# 2021_10 Veidekke Mal MSP

Schedule from MS Project, 2025-09-11 to 2029-11-30, A marks actual dates.

## Calendars

- Standard: Mon-Fri 08:00-12:00, 13:00-17:00; Sat-Sun off. Exceptions (off unless hours are given): 2025-12-24 to 2026-01-01 (Juleferie 2025), 2026-03-30 to 2026-04-06 (Påske 2026), 2026-05-01 (1. mai 2026), 2026-05-14 (Kr. Himmelfart 2026), 2026-05-25 (2. Pinsedag 2026), 2026-07-06 to 2026-07-18 (Fellesferie 2026), 2026-07-19 08:00-12:00, 13:00-17:00, 2026-07-20 to 2026-07-24 (Fellesferie 2026), 2026-12-24 to 2027-01-01 (Juleferie 2026), 2027-03-22 to 2027-03-29 (Påske 2027), 2027-05-06 (Kr Himmelfart 2027), 2027-05-16 (1. pinsedag 2027), 2027-05-17 (17 mai/2. pinsedag 2027), 2027-07-05 to 2027-08-01 (Fellesferie 2027), 2027-12-24 to 2028-01-01 (Juleferie 2027), 2028-04-09 to 2028-04-17 (Påske 2028), 2028-05-01 (1. mai 2028), 2028-05-17 (17.mai 2028), 2028-05-25 (Kr Himmelfart 2028), 2028-06-04 to 2028-06-05 (Pinse 2028), 2028-07-03 to 2028-07-30 (Fellesferie 2028), 2028-10-28 08:00-12:00, 13:00-17:00, 2028-12-24 to 2029-01-01 (Juleferie 2028).
- Rørvegg: Mon-Fri 08:00-12:00, 13:00-17:00; Sat-Sun off. Exceptions (off unless hours are given): 2025-12-24 to 2026-01-01 (Juleferie 2025), 2026-03-30 to 2026-04-06 (Påske 2026), 2026-05-01 (1. mai 2026), 2026-05-14 (Kr. Himmelfart 2026), 2026-05-25 (2. Pinsedag 2026), 2026-12-24 to 2027-01-01 (Juleferie 2026), 2027-03-22 to 2027-03-29 (Påske 2027), 2027-05-06 (Kr Himmelfart 2027), 2027-05-16 (1. pinsedag 2027), 2027-05-17 (17 mai/2. pinsedag 2027), 2027-07-05 to 2027-08-01 (Fellesferie 2027), 2027-12-24 to 2028-01-01 (Juleferie 2027), 2028-04-09 to 2028-04-17 (Påske 2028), 2028-05-01 (1. mai 2028), 2028-05-17 (17.mai 2028), 2028-05-25 (Kr Himmelfart 2028), 2028-06-04 to 2028-06-05 (Pinse 2028), 2028-07-03 to 2028-07-30 (Fellesferie 2028), 2028-12-24 to 2029-01-01 (Juleferie 2028).

## Schedule

| ID | WBS | Task | Type | Duration | Start | Finish | Predecessors | Complete | Remaining | Baseline start | Baseline finish | Baseline duration | Total slack | Free slack | Constraint | Ukenummer | År | Ressurser |
| --- | --- | --- | --- | --- | --- | --- | --- | --- | --- | --- | --- | --- | --- | --- | --- | --- | --- | --- |
| 1 | 1 | **Griegakademiet** |  | 996d? | 2025-09-11 A | 2029-11-30 |  | 9% | 906.27d? | 2025-09-11 | 2029-10-18 | 963d? | 0d |  |  | Uke 37 | 2025 |  |
| 2 | 1.1 | **Byggherre** |  | 0d | 2026-01-30 A | 2026-01-30 A |  | 100% |  | 2026-01-21 | 2026-01-21 | 0d |  |  |  | Uke 37 | 2025 |  |
| 3 | 1.1.1 | Godkjent optimaliseringsfase | milestone | 0d | 2026-01-30 A | 2026-01-30 A | 61 | 100% |  | 2026-01-21 | 2026-01-21 | 0d |  |  | start no earlier than 2025-12-19 | Uke 5 | 2026 |  |
| 4 | 1.2 | **Milepæler kontrakt** |  | 911d? | 2026-01-19 A | 2029-11-30 |  |  | 911d? | 2026-01-19 | 2029-10-18 | 878d | 0d |  |  | Uke 37 | 2025 |  |
| 5 | 1.2.1 | Utarbeidelse av fremdriftsplan | milestone | 0d | 2026-01-19 A | 2026-01-19 A |  | 100% |  | 2026-01-19 | 2026-01-19 | 0d |  |  | start no earlier than 2026-01-19 | Uke 4 | 2026 |  |
| 6 | 1.2.2 | **Systemmatisk ferdigstillelse** |  | 563d | 2026-05-05 | 2028-10-28 |  |  |  | 2026-03-12 | 2028-10-06 | 577d | 279d |  |  | Uke 37 | 2025 |  |
| 7 | 1.2.2.1 | Integrerte funksjonsbeskrivelser, systemlister | milestone | 0d | 2026-05-12 | 2026-05-12 |  |  |  | 2026-04-16 | 2026-04-16 | 0d | 837d |  | start no earlier than 2026-05-12 | Uke 20 | 2026 |  |
| 8 | 1.2.2.2 | Funksjonsbeskrivelser | milestone | 0d | 2026-05-05 | 2026-05-05 |  |  |  | 2026-03-12 | 2026-03-12 | 0d | 842d |  | start no earlier than 2026-05-05 | Uke 19 | 2026 |  |
| 9 | 1.2.2.3 | Tabeltester (godkjent, min 10 tabeltester) | milestone | 0d | 2026-06-19 | 2026-06-19 |  |  |  | 2026-09-17 | 2026-09-17 | 0d | 811d |  | start no earlier than 2026-06-19 | Uke 25 | 2026 |  |
| 10 | 1.2.2.4 | Mekanisk ferdigstilt - siste område | milestone | 0d | 2028-08-04 | 2028-08-04 | 18FS-86d |  |  |  |  |  | 16d | 0d | start no later than 2028-08-28 | Uke 31 | 2028 |  |
| 11 | 1.2.2.5 | Siste integrerte test | milestone | 0d | 2028-10-14 | 2028-10-14 | 10FS+51d |  |  | 2028-09-22 | 2028-09-22 | 0d | 159d | 0d | finish no earlier than 2028-10-14 | Uke 41 | 2028 |  |
| 12 | 1.2.2.6 | Fullskalatest | milestone | 0d | 2028-10-28 | 2028-10-28 | 11FS+11d |  |  | 2028-10-06 | 2028-10-06 | 0d | 159d | 0d |  | Uke 43 | 2028 |  |
| 13 | 1.2.2.7 | FDV innleveres fortløpende. Siste leveranse før endelig versjon | milestone | 0d | 2028-09-11 | 2028-09-11 | 11FS-5.1w |  |  | 2028-09-11 | 2028-09-11 | 0d | 315d |  | start no earlier than 2028-09-11 | Uke 37 | 2028 |  |
| 14 | 1.2.3 | Byggherrens beslutningsplan | milestone | 0d | 2026-02-10 A | 2026-02-10 A |  | 100% |  | 2026-01-21 | 2026-01-21 | 0d |  |  | start no earlier than 2026-02-10 | Uke 7 | 2026 |  |
| 15 | 1.2.4 | Igangsetting byggeplass |  | 1d? | 2026-06-15 | 2026-06-15 | 25FS+8d |  |  |  |  |  | 814d |  |  | Uke 25 | 2026 |  |
| 16 | 1.2.5 | Bygning ferdig rengjort (Byggvask 2) | milestone | 0d | 2028-11-11 | 2028-11-11 | 12FS+10d |  |  | 2028-10-20 | 2028-10-20 | 0d | 269d |  | finish no earlier than 2028-11-11 | Uke 45 | 2028 |  |
| 17 | 1.2.6 | Overlevering endelig FDV-dokumentasjon | milestone | 0d | 2029-01-11 | 2029-01-11 | 18SS+1.16mo |  |  | 2029-01-11 | 2029-01-11 | 0d | 231.8d |  |  | Uke 2 | 2029 |  |
| 18 | 1.2.7 | Oppstart prøvedrift | milestone | 0d | 2028-12-01 | 2028-12-01 | 638SS |  |  | 2028-11-09 | 2028-11-09 | 0d | 0d |  | start no earlier than 2028-12-01 | Uke 48 | 2028 |  |
| 19 | 1.2.8 | Overtakelse | milestone | 0d | 2029-11-30 | 2029-11-30 | 18FS+12.75mo |  |  | 2029-10-18 | 2029-10-18 | 0d | 0d |  |  | Uke 48 | 2029 |  |
| 21 | 1.3 | **Milepæler** |  | 545d? | 2025-09-11 A | 2028-01-20 |  | 7% | 508.67d? | 2026-02-19 | 2027-12-03 | 408d | 451d |  |  | Uke 37 | 2025 |  |
| 22 | 1.3.1 | Grunnstein |  | 1d? | 2026-08-13 | 2026-08-13 |  |  |  |  |  |  | 785d |  | start no earlier than 2026-08-13 | Uke 33 | 2026 |  |
| 23 | 1.3.2 | Kickoff |  | 1d | 2026-01-26 A | 2026-01-26 A |  | 100% |  |  |  |  |  |  | start no earlier than 2026-01-26 | Uke 5 | 2026 |  |
| 24 | 1.3.3 | Desigmanual etablert | milestone | 0d | 2026-05-08 | 2026-05-08 |  |  |  |  |  |  | 839d |  | start no earlier than 2026-05-08 | Uke 19 | 2026 |  |
| 25 | 1.3.4 | Oppstart byggeplass | milestone | 0d | 2026-06-03 | 2026-06-03 |  |  |  | 2026-04-30 | 2026-04-30 | 0d | 14d | 0d | start no earlier than 2026-06-03 | Uke 23 | 2026 |  |
| 26 | 1.3.5 | Underlag SLLB fra UIB plan 2-4 | milestone | 0d | 2026-04-10 | 2026-04-10 |  |  |  |  |  |  | 858d |  | start no earlier than 2026-04-10 | Uke 15 | 2026 | UIB |
| 27 | 1.3.6 | Underlag SLLb fra UIB plan 1 | milestone | 0d | 2026-06-19 | 2026-06-19 |  |  |  |  |  |  | 811d |  | start no earlier than 2026-06-19 | Uke 25 | 2026 | UIB |
| 28 | 1.3.7 | Verifisering av vibrasjoner etter etablering av fundamenter |  | 2d | 2025-09-11 | 2025-09-12 |  |  |  |  |  |  | 994d |  |  | Uke 37 | 2025 |  |
| 29 | 1.3.8 | Etablering av "prøverom" for kontroll av lydsmitte - verifisere løsninger |  | 2w | 2027-11-08 | 2027-11-19 | 397FS+2w |  |  |  |  |  | 489d |  |  | Uke 45 | 2027 |  |
| 30 | 1.3.9 | Oppstartsmøte systematisk ferdigstillelse (PA0701-2) - pkt 3.1 |  | 1d | 2026-02-19 | 2026-02-19 |  |  |  | 2026-02-19 | 2026-02-19 | 1d | 887d |  | start no earlier than 2026-02-19 | Uke 8 | 2026 |  |
| 31 | 1.3.10 | Råbygg ferdig | milestone | 0d | 2027-08-30 | 2027-08-30 | 289 |  |  | 2027-06-09 | 2027-06-09 | 0d | 548d |  |  | Uke 35 | 2027 |  |
| 32 | 1.3.11 | Tetthus | milestone | 0d | 2028-01-20 | 2028-01-20 | 375 |  |  | 2027-12-03 | 2027-12-03 | 0d | 451d |  |  | Uke 3 | 2028 |  |
| 33 | 1.3.12 | Hovedtavle klar for strømsetting | milestone | 0d | 2027-12-15 | 2027-12-15 | 631 |  |  |  |  |  | 471d |  |  | Uke 50 | 2027 |  |
| 34 | 1.3.13 | Fjernvarme klar for byggoppvarming | milestone | 0d | 2027-09-13 | 2027-09-13 | 397SS-2w |  |  |  |  |  | 539d |  |  | Uke 37 | 2027 |  |
| 35 | 1.3.14 | SHA-plan | milestone | 0d | 2026-04-17 | 2026-04-17 |  |  |  |  |  |  | 853d |  | start no earlier than 2026-04-17 | Uke 16 | 2026 | Statsbygg |

Notes:
- 9: Funksjonsbeskrivelser ferdig 30.04.26 / U18/26 / SB/UIB får 2 uker for gjennomgang. / U19-U21/26 / Oppstart felles gjennomganger U22/26 - Ferdig U24

| ID | WBS | Task | Type | Duration | Start | Finish | Predecessors | Complete | Remaining | Baseline start | Baseline finish | Baseline duration | Total slack | Free slack | Constraint | Ukenummer | År | Ressurser |
| --- | --- | --- | --- | --- | --- | --- | --- | --- | --- | --- | --- | --- | --- | --- | --- | --- | --- | --- |
| 36 | 1.4 | **Risikogjennomgang IG** |  | 114d | 2026-06-01 | 2026-11-25 |  |  |  |  |  |  | 711d |  |  | Uke 37 | 2025 |  |
| 37 | 1.4.1 | Risikogjennomgang IG1 |  | 1d | 2026-06-01 | 2026-06-01 | 54FF-3w |  |  |  |  |  | 824d |  |  | Uke 23 | 2026 |  |
| 38 | 1.4.2 | Risikogjennomgang IG2 |  | 1d | 2026-08-28 | 2026-08-28 | 55FF-3w |  |  |  |  |  | 774d |  |  | Uke 35 | 2026 |  |
| 39 | 1.4.3 | Risikogjennomgang IG3 |  | 1d | 2026-10-14 | 2026-10-14 | 56FF-3w |  |  |  |  |  | 741d |  |  | Uke 42 | 2026 |  |
| 40 | 1.4.4 | Risikogjennomgang IG4 |  | 1d | 2026-11-25 | 2026-11-25 | 57FF-3w |  |  |  |  |  | 711d |  |  | Uke 48 | 2026 |  |
| 41 | 1.5 | **Myndigheter** |  | 837d? | 2025-09-11 A | 2029-04-23 |  | 69% | 255.62d? | 2025-10-06 | 2029-02-08 | 766d | 159d |  |  | Uke 37 | 2025 |  |
| 42 | 1.5.1 | Nabovarsel |  | 3w | 2025-10-13 A | 2025-10-31 A |  | 100% |  | 2025-10-13 | 2025-10-31 | 3w |  |  | finish no earlier than 2025-10-31 | Uke 42 | 2025 |  |
| 43 | 1.5.2 | Rammesøknad |  | 3.5mo | 2025-12-05 A | 2026-03-23 | 42FS+5d | 80% | 0.7mo | 2025-12-05 | 2026-03-23 | 3.5mo | 28d | 0d | start no earlier than 2025-12-05 | Uke 49 | 2025 |  |
| 44 | 1.5.3 | Teknisk plan veg |  | 4mo | 2025-10-17 A | 2026-02-16 |  | 80% | 0.8mo | 2025-10-17 | 2026-02-16 | 4mo | 890d |  | start no earlier than 2025-10-17 | Uke 42 | 2025 |  |
| 45 | 1.5.4 | Teknisk plan VAO |  | 4mo | 2025-10-06 A | 2026-02-03 |  | 80% | 0.8mo | 2025-10-06 | 2026-02-03 | 4mo | 899d |  | start no earlier than 2025-10-06 | Uke 41 | 2025 |  |
| 46 | 1.5.5 | Tiltaksplan forurenset grunn |  | 4w | 2026-02-25 A | 2026-03-25 A | 25SF-1mo | 100% |  | 2026-02-25 | 2026-03-25 | 4w |  |  | start no earlier than 2026-01-19 | Uke 9 | 2026 |  |
| 47 | 1.5.6 | Dispensasjon Bane Nor |  | 4mo | 2025-10-27 A | 2026-02-24 |  | 70% | 1.2mo | 2025-10-27 | 2026-02-24 | 4mo | 884d |  | start no earlier than 2025-10-27 | Uke 44 | 2025 |  |
| 48 | 1.5.7 | Dispensasjon Bybanen |  | 3mo | 2025-11-04 A | 2026-02-04 A |  | 100% |  | 2025-11-04 | 2026-02-04 | 3mo |  |  | start no earlier than 2025-11-04 | Uke 45 | 2025 |  |
| 49 | 1.5.8 | Forhåndsmelding til Arbeidstilsynet |  | 1d? | 2026-04-27 | 2026-04-27 |  |  |  |  |  |  | 846d |  | start no earlier than 2026-04-27 | Uke 18 | 2026 | Statsbygg |
| 50 | 1.5.9 | Arbeidsvarsling |  | 2w | 2026-03-18 A | 2026-04-09 A | 25SF-3w | 100% |  | 2026-03-18 | 2026-04-09 | 2w |  |  |  | Uke 12 | 2026 |  |
| 51 | 1.5.10 | Arbeidsvarsling Bybane |  | 2w | 2026-04-24 | 2026-05-11 | 25SF-3w |  |  | 2026-03-18 | 2026-04-09 | 2w | 838d |  |  | Uke 17 | 2026 |  |
| 52 | 1.5.11 | Arbeidsvarsling Bane Nor |  | 2w | 2026-04-24 | 2026-05-11 | 25SF-3w |  |  | 2026-03-18 | 2026-04-09 | 2w | 838d |  |  | Uke 17 | 2026 |  |
| 53 | 1.5.12 | Søknad Arbeidstilsynets samtykke til permanente arbeidsplasser |  | 2mo | 2026-03-24 A | 2026-05-29 | 43 | 70% | 0.6mo | 2026-03-24 | 2026-05-29 | 2mo | 825d |  |  | Uke 13 | 2026 |  |
| 54 | 1.5.13 | Søknad 01 - IG grunnarbeider, spunt, peling, sanitær og VAO, VA kulvert |  | 3w | 2026-06-02 | 2026-06-22 | 25SF, 43 |  |  | 2026-04-09 | 2026-04-30 | 3w | 0d |  | finish no earlier than 2026-06-22 | Uke 23 | 2026 |  |
| 55 | 1.5.14 | Søknad 02 - IG råbygg |  | 3w | 2026-08-31 | 2026-09-18 | 292SS-60d |  |  | 2026-04-23 | 2026-05-15 | 3w | 759d | 0d | start no earlier than 2026-04-23 | Uke 36 | 2026 |  |
| 56 | 1.5.15 | Søknad 03 - Tetthus |  | 3w | 2026-10-15 | 2026-11-04 | 376SS-150d |  |  | 2026-08-06 | 2026-08-26 | 3w | 726d | 0d | start no earlier than 2026-08-06 | Uke 42 | 2026 |  |
| 57 | 1.5.16 | Søknad IG 04 - Innvendige arbeider inkl tekniske |  | 3w | 2026-11-26 | 2026-12-16 | 394SS-180d |  |  | 2026-09-15 | 2026-10-05 | 3w | 696d | 0d | start no earlier than 2026-09-15 | Uke 48 | 2026 |  |
| 58 | 1.5.17 | Søknad om midlertidig brukstilltelse | milestone | 0d | 2028-10-28 | 2028-10-28 | 18FS-6w, 12 |  |  | 2028-10-12 | 2028-10-12 | 0d | 159d | 0d |  | Uke 43 | 2028 |  |
| 59 | 1.5.18 | Søknad om ferdigattest | milestone | 0d | 2029-04-23 | 2029-04-23 | 58FS+6mo |  |  | 2029-02-08 | 2029-02-08 | 0d | 159d |  |  | Uke 17 | 2029 |  |
| 60 | 1.5.19 | Søknad skoleetaten |  | 1d? | 2025-09-11 | 2025-09-11 |  |  |  |  |  |  | 995d |  |  | Uke 37 | 2025 |  |
| 61 | 1.6 | Optimaliseringsfase |  | 95d | 2025-09-11 | 2026-01-30 |  |  |  | 2025-09-11 | 2026-01-21 | 88d | 901d |  |  | Uke 37 | 2025 |  |

| ID | WBS | Task | Type | Duration | Start | Finish | Predecessors | Complete | Remaining | Baseline start | Baseline finish | Baseline duration | Total slack | Constraint | Ukenummer | År | Ressurser |
| --- | --- | --- | --- | --- | --- | --- | --- | --- | --- | --- | --- | --- | --- | --- | --- | --- | --- |
| 62 | 1.7 | **INNKJØP (kritisk linje )** |  | 128d | 2025-09-11 A | 2026-03-19 |  | 93% | 9.14d | 2025-09-11 | 2026-03-19 | 128d | 868d |  |  |  |  |
| 63 | 1.7.1 | Kontraheringer rådgivere |  | 50d | 2025-09-11 A | 2025-11-19 A |  | 100% |  | 2025-09-11 | 2025-11-19 | 50d |  |  | Uke 37 | 2025 |  |
| 64 | 1.7.2 | Grunnarbeider | milestone | 0d | 2025-09-11 A | 2025-09-11 A |  | 100% |  | 2025-09-11 | 2025-09-11 | 0d |  |  | Uke 37 | 2025 |  |
| 65 | 1.7.3 | Spunt- og pelearbeider |  | 10d | 2026-02-09 A | 2026-02-20 | 3FS+1w | 70% | 3d | 2026-01-29 | 2026-02-11 | 10d | 886d |  | Uke 7 | 2026 |  |
| 66 | 1.7.4 | Plasstøpt betong bygg under bakken | milestone | 0d | 2025-09-11 A | 2025-09-11 A |  | 100% |  | 2025-09-11 | 2025-09-11 | 0d |  |  | Uke 37 | 2025 |  |
| 67 | 1.7.5 | Råbygg over kjeller |  | 10d | 2026-02-09 A | 2026-02-20 | 3FS+1w | 80% | 2d | 2026-01-29 | 2026-02-11 | 10d | 886d |  | Uke 7 | 2026 |  |
| 68 | 1.7.6 | Tømrer tett hus | milestone | 0d | 2025-09-11 A | 2025-09-11 A |  | 100% |  | 2025-09-11 | 2025-09-11 | 0d |  |  | Uke 37 | 2025 |  |
| 69 | 1.7.7 | Heiser | milestone | 0d | 2026-01-23 A | 2026-01-23 |  | 90% | 0d | 2026-01-23 | 2026-01-23 | 0d | 907d | start no earlier than 2026-01-23 | Uke 4 | 2026 |  |
| 70 | 1.7.8 | Vinduer | milestone | 0d | 2026-03-09 | 2026-03-09 |  |  |  | 2026-03-09 | 2026-03-09 | 0d | 876d | start no earlier than 2026-03-09 | Uke 11 | 2026 |  |
| 71 | 1.7.9 | Glassfasader | milestone | 0d | 2026-03-19 | 2026-03-19 |  |  |  | 2026-03-19 | 2026-03-19 | 0d | 868d | start no earlier than 2026-03-19 | Uke 12 | 2026 |  |
| 72 | 1.7.10 | Rørlegger | milestone | 0d | 2025-09-11 A | 2025-09-11 A |  | 100% |  | 2025-09-11 | 2025-09-11 | 0d |  |  | Uke 37 | 2025 |  |
| 73 | 1.7.11 | Ventilasjon | milestone | 0d | 2025-09-11 A | 2025-09-11 A |  | 100% |  | 2025-09-11 | 2025-09-11 | 0d |  |  | Uke 37 | 2025 |  |
| 74 | 1.7.12 | Elektro | milestone | 0d | 2025-09-11 A | 2025-09-11 A |  | 100% |  | 2025-09-11 | 2025-09-11 | 0d |  |  | Uke 37 | 2025 |  |
| 75 | 1.8 | **FDVU** |  | 506d | 2026-03-27 A | 2028-06-16 |  | 99% | 0d |  |  |  | 356d |  | Uke 37 | 2025 |  |
| 76 | 1.8.1 | Oppstartsmøte |  | 1d | 2026-03-27 A | 2026-03-27 A |  | 100% |  |  |  |  |  | start no earlier than 2026-03-27 | Uke 13 | 2026 | Statsbygg |
| 77 | 1.8.2 | **FDVU-leveranser** |  | 160d | 2027-10-14 | 2028-06-16 |  |  |  |  |  |  | 356d |  | Uke 37 | 2025 |  |
| 78 | 1.8.2.1 | MC Plan 4 sone A | milestone | 0d | 2028-02-03 | 2028-02-03 | 410SS-1w |  |  |  |  |  | 442d |  | Uke 5 | 2028 |  |
| 79 | 1.8.2.2 | MC Plan 4 sone B | milestone | 0d | 2028-02-10 | 2028-02-10 | 422SS-1w |  |  |  |  |  | 437d |  | Uke 6 | 2028 |  |
| 80 | 1.8.2.3 | MC Plan 4 sone C | milestone | 0d | 2028-02-17 | 2028-02-17 | 434SS-1w |  |  |  |  |  | 432d |  | Uke 7 | 2028 |  |
| 81 | 1.8.2.4 | MC Plan 3 sone A | milestone | 0d | 2028-03-10 | 2028-03-10 | 453SS-1w |  |  |  |  |  | 416d |  | Uke 10 | 2028 |  |
| 82 | 1.8.2.5 | MC Plan 3 sone B | milestone | 0d | 2028-03-31 | 2028-03-31 | 465SS-1w |  |  |  |  |  | 401d |  | Uke 13 | 2028 |  |
| 83 | 1.8.2.6 | MC Plan 3 sone C | milestone | 0d | 2028-05-03 | 2028-05-03 | 477SS-1w |  |  |  |  |  | 385d |  | Uke 18 | 2028 |  |
| 84 | 1.8.2.7 | MC Plan 2 sone A | milestone | 0d | 2028-01-25 | 2028-01-25 | 495SS-1w |  |  |  |  |  | 449d |  | Uke 4 | 2028 |  |
| 85 | 1.8.2.8 | MC Plan 2 sone B | milestone | 0d | 2028-02-01 | 2028-02-01 | 507SS-1w |  |  |  |  |  | 444d |  | Uke 5 | 2028 |  |
| 86 | 1.8.2.9 | MC Plan 2 sone C | milestone | 0d | 2028-06-01 | 2028-06-01 | 519SS-1w |  |  |  |  |  | 366d |  | Uke 22 | 2028 |  |
| 87 | 1.8.2.10 | MC Plan 1 sone A | milestone | 0d | 2028-05-02 | 2028-05-02 | 536SS-1w |  |  |  |  |  | 386d |  | Uke 18 | 2028 |  |
| 88 | 1.8.2.11 | MC Plan 1 sone B | milestone | 0d | 2028-03-24 | 2028-03-24 | 549FS-2mo |  |  |  |  |  | 406d |  | Uke 12 | 2028 |  |
| 89 | 1.8.2.12 | MC Plan 1 - Konsertsal | milestone | 0d | 2028-06-16 | 2028-06-16 | 570SS-1w |  |  |  |  |  | 356d |  | Uke 24 | 2028 |  |
| 90 | 1.8.2.13 | MC Plan 1 - Blackboks | milestone | 0d | 2027-10-14 | 2027-10-14 | 596SS-1w |  |  |  |  |  | 516d |  | Uke 41 | 2027 |  |
| 91 | 1.8.2.14 | MC Plan 1 - Kammersal | milestone | 0d | 2028-03-31 | 2028-03-31 | 609SS-1w |  |  |  |  |  | 401d |  | Uke 13 | 2028 |  |
| 92 | 1.8.2.15 | MC Plan 1 - Opptaksstudio | milestone | 0d | 2028-05-24 | 2028-05-24 | 625SS-1w |  |  |  |  |  | 371d |  | Uke 21 | 2028 |  |
| 93 | 1.8.2.16 | MC Plan U | milestone | 0d | 2028-02-18 | 2028-02-18 | 630FS-1mo |  |  |  |  |  | 431d |  | Uke 7 | 2028 |  |

| ID | WBS | Task | Type | Duration | Start | Finish | Predecessors | Total slack | Free slack | Constraint | Ukenummer | År |
| --- | --- | --- | --- | --- | --- | --- | --- | --- | --- | --- | --- | --- |
| 94 | 1.9 | **Møter** |  | 194d? | 2025-09-11 | 2026-07-02 |  | 802d |  |  | Uke 37 | 2025 |
| 95 | 1.9.1 | **Byggherremøter** |  | 96d | 2026-02-05 | 2026-07-02 |  | 802d |  |  | Uke 37 | 2025 |
| 96 | 1.9.1.1 | **Byggherremøte 1. halvår 2026** |  | 96d | 2026-02-05 | 2026-07-02 |  | 802d |  |  | Uke 37 | 2025 |
| 97 | 1.9.1.1.1 | Byggherremøte 7 | milestone | 0d | 2026-02-19 | 2026-02-19 |  | 888d |  | start no earlier than 2026-02-19 | Uke 8 | 2026 |
| 98 | 1.9.1.1.2 | Byggherremøte 8 | milestone | 0d | 2026-03-05 | 2026-03-05 |  | 878d |  | start no earlier than 2026-03-05 | Uke 10 | 2026 |
| 99 | 1.9.1.1.3 | Byggherremøte 9 | milestone | 0d | 2026-03-19 | 2026-03-19 |  | 868d |  | start no earlier than 2026-03-19 | Uke 12 | 2026 |
| 100 | 1.9.1.1.4 | Byggherremøte 10 | milestone | 0d | 2026-02-05 | 2026-02-05 |  | 898d |  | start no earlier than 2026-02-05 | Uke 6 | 2026 |
| 101 | 1.9.1.1.5 | Byggherremøte 11 | milestone | 0d | 2026-04-23 | 2026-04-23 |  | 849d |  | start no earlier than 2026-04-23 | Uke 17 | 2026 |
| 102 | 1.9.1.1.6 | Byggherremøte 12 | milestone | 0d | 2026-05-07 | 2026-05-07 |  | 840d |  | start no earlier than 2026-05-07 | Uke 19 | 2026 |
| 103 | 1.9.1.1.7 | Byggherremøte 13 | milestone | 0d | 2026-05-21 | 2026-05-21 |  | 831d |  | start no earlier than 2026-05-21 | Uke 21 | 2026 |
| 104 | 1.9.1.1.8 | Byggherremøte 14 | milestone | 0d | 2026-06-04 | 2026-06-04 |  | 822d |  | start no earlier than 2026-06-04 | Uke 23 | 2026 |
| 105 | 1.9.1.1.9 | Byggherremøte 15 | milestone | 0d | 2026-06-18 | 2026-06-18 |  | 812d |  | start no earlier than 2026-06-18 | Uke 25 | 2026 |
| 106 | 1.9.1.1.10 | Byggherremøte 16 | milestone | 0d | 2026-07-02 | 2026-07-02 |  | 802d |  | start no earlier than 2026-07-02 | Uke 27 | 2026 |
| 107 | 1.9.2 | Prosjekteringsmøter |  | 1d? | 2025-09-11 | 2025-09-11 |  | 995d |  |  | Uke 37 | 2025 |
| 108 | 1.9.3 | BIM-møter |  | 1d? | 2025-09-11 | 2025-09-11 |  | 995d |  |  | Uke 37 | 2025 |
| 109 | 1.9.4 | **ITB-møter** |  | 68d | 2026-02-04 | 2026-05-20 |  | 831d |  |  | Uke 37 | 2025 |
| 110 | 1.9.4.1 | Oppstartsmøte ITB | milestone | 0d | 2026-02-04 | 2026-02-04 |  | 831d | 0d | start no earlier than 2026-02-04 | Uke 6 | 2026 |
| 111 | 1.9.4.2 | ITB-møte | milestone | 0d | 2026-02-18 | 2026-02-18 | 110FS+11d | 831d | 0d |  | Uke 8 | 2026 |
| 112 | 1.9.4.3 | ITB-møte | milestone | 0d | 2026-03-04 | 2026-03-04 | 111FS+10d | 831d | 0d |  | Uke 10 | 2026 |
| 113 | 1.9.4.4 | ITB-møte | milestone | 0d | 2026-03-18 | 2026-03-18 | 112FS+10d | 831d | 0d |  | Uke 12 | 2026 |
| 114 | 1.9.4.5 | ITB-møte | milestone | 0d | 2026-04-09 | 2026-04-09 | 113FS+10d | 831d | 0d |  | Uke 15 | 2026 |
| 115 | 1.9.4.6 | ITB-møte | milestone | 0d | 2026-04-22 | 2026-04-22 | 114FS+9d | 831d | 0d |  | Uke 17 | 2026 |
| 116 | 1.9.4.7 | ITB-møte | milestone | 0d | 2026-05-06 | 2026-05-06 | 115FS+9d | 831d | 0d |  | Uke 19 | 2026 |
| 117 | 1.9.4.8 | ITB-møte | milestone | 0d | 2026-05-20 | 2026-05-20 | 116FS+9d | 831d |  |  | Uke 21 | 2026 |

| ID | WBS | Task | Type | Duration | Start | Finish | Predecessors | Complete | Remaining | Baseline start | Baseline finish | Baseline duration | Total slack | Free slack | Constraint | Ukenummer | År | Ressurser |
| --- | --- | --- | --- | --- | --- | --- | --- | --- | --- | --- | --- | --- | --- | --- | --- | --- | --- | --- |
| 118 | 1.10 | **Detaljprosjektering** |  | 301d? | 2025-09-11 A | 2026-12-17 |  | 4% | 288.06d? | 2026-01-21 | 2026-10-20 | 170d | 695d |  |  | Uke 37 | 2025 |  |
| 119 | 1.10.1 | Oppstart detaljprosjektering | milestone | 0d | 2026-01-30 A | 2026-01-30 A | 3 | 100% |  | 2026-01-21 | 2026-01-21 | 0d |  |  |  | Uke 5 | 2026 |  |
| 120 | 1.10.2 | Møbleringsplan |  | 34d | 2026-02-03 A | 2026-03-20 A | 119 | 100% |  |  |  |  |  |  | start no earlier than 2026-02-03 | Uke 6 | 2026 | UIB |
| 121 | 1.10.3 | Forankring UIB, SB, VD, RI, ARK | milestone | 0d | 2026-03-20 A | 2026-03-20 A | 120 | 100% |  |  |  |  |  |  |  | Uke 12 | 2026 |  |
| 122 | 1.10.4 | **Designhåndbok** |  | 29d? | 2026-03-16 A | 2026-05-04 |  | 17% | 23.94d? |  |  |  | 842d |  |  | Uke 37 | 2025 |  |
| 123 | 1.10.4.1 | Workshop UIB (ARK) |  | 1d? | 2026-03-16 A | 2026-03-16 A | 120FS-5d | 100% |  |  |  |  |  |  |  | Uke 12 | 2026 |  |
| 124 | 1.10.4.2 | Del 1 - Visjoner og inntrykk |  | 10d | 2026-03-16 A | 2026-03-27 A | 120FS-5d | 100% |  |  |  |  |  |  |  | Uke 12 | 2026 |  |
| 125 | 1.10.4.3 | Forakring UIB | milestone | 0d | 2026-03-26 A | 2026-03-26 A | 124FS-2d | 100% |  |  |  |  |  |  |  | Uke 13 | 2026 |  |
| 126 | 1.10.4.4 | **Del 2 - Konseptarbeider** |  | 19d | 2026-04-07 A | 2026-05-04 |  |  | 19d |  |  |  | 842d |  |  | Uke 37 | 2025 |  |
| 127 | 1.10.4.4.1 | Workshop UIB, ARK | milestone | 0d | 2026-04-07 A | 2026-04-07 A |  | 100% |  |  |  |  |  |  | start no earlier than 2026-04-07 | Uke 15 | 2026 |  |
| 128 | 1.10.4.4.2 | Konsept materialer og farger utvendig, konsept utomhus - ARK, LARK |  | 12d | 2026-04-07 | 2026-04-22 | 127 |  |  |  |  |  | 842d | 0d |  | Uke 15 | 2026 |  |
| 129 | 1.10.4.4.3 | Konsept materialer og farger innvendig (gulv, vegger, himlinger, tekniske installasjoner, fast inventar) - ARK, IARK UIB |  | 19d | 2026-04-07 | 2026-05-04 | 128SS |  |  |  |  |  | 842d |  |  | Uke 15 | 2026 |  |
| 130 | 1.10.4.4.4 | Teknisk utstyr og tekniske krav ift akustikk (SLLB) - koordinering mot bygg, belysning fremføringsrom - SLLB UIB, ARK, IARK UIB, RIELysdesigner, RIAku VD |  | 6d | 2026-04-21 | 2026-04-28 | 128SS+10d |  |  |  |  |  | 845d |  |  | Uke 17 | 2026 |  |
| 131 | 1.10.4.4.5 | Konsept belysning - øvrige areal - RIELysdesigner, ARK, IARK UIB, RIAku VD |  | 6d | 2026-04-21 | 2026-04-28 | 128SS+10d |  |  |  |  |  | 845d |  |  | Uke 17 | 2026 |  |
| 132 | 1.10.4.4.6 | Konsept løst inventar - IARK UIB |  | 9d | 2026-04-21 | 2026-05-04 | 128SS+10d |  |  |  |  |  | 842d | 0d |  | Uke 17 | 2026 |  |
| 133 | 1.10.4.4.7 | Statusmøte (SB, UIB, VD) | milestone | 0d | 2026-04-20 | 2026-04-20 | 134SS-2w |  |  |  |  |  | 852d |  |  | Uke 17 | 2026 |  |
| 134 | 1.10.4.4.8 | Forankring av konseptarbeider | milestone | 0d | 2026-05-04 | 2026-05-04 | 132 |  |  |  |  |  | 842d | 0d |  | Uke 19 | 2026 |  |
| 135 | 1.10.5 | **Prosjektering for IG1** |  | 161d? | 2025-09-11 | 2026-05-15 |  |  |  |  |  |  | 695d | 0d |  |  |  |  |
| 136 | 1.10.5.1 | LP1 | milestone | 0d | 2026-05-15 | 2026-05-15 | 54SF-11d |  |  |  |  |  | 695d | 0d |  | Uke 20 | 2026 |  |
| 137 | 1.10.5.2 | KS-LP1 |  | 5d | 2026-05-04 | 2026-05-11 | 136SF-3d |  |  |  |  |  | 698d | 0d |  | Uke 19 | 2026 |  |
| 138 | 1.10.5.3 | **BIM** |  | 20d | 2026-03-19 | 2026-04-24 |  |  |  |  |  |  | 708d |  |  |  |  |  |
| 139 | 1.10.5.3.1 | Sammenstilling-MMI 350-TK-IG 01 |  | 10d | 2026-03-19 | 2026-04-10 | 140SF |  |  |  |  |  | 718d |  | finish no earlier than 2025-11-04 | Uke 12 | 2026 |  |
| 140 | 1.10.5.3.2 | Sammenstilling-MMI 400-AG-IG 01 |  | 10d | 2026-04-10 | 2026-04-24 | 137SF-5d |  |  |  |  |  | 708d | 0d | finish no earlier than 2025-11-04 | Uke 15 | 2026 |  |
| 141 | 1.10.5.4 | **RIG** |  | 23d | 2026-03-16 | 2026-04-24 |  |  |  |  |  |  | 708d |  |  |  |  |  |
| 142 | 1.10.5.4.1 | RIG-MMI 350-TK-IG 01 |  | 10d | 2026-03-19 | 2026-04-10 | 143SF |  |  |  |  |  | 718d |  | finish no earlier than 2025-11-04 | Uke 12 | 2026 |  |
| 143 | 1.10.5.4.2 | RIG-MMI 400-AG-IG 01 |  | 10d | 2026-04-10 | 2026-04-24 | 137SF-5d |  |  |  |  |  | 708d | 0d | finish no earlier than 2025-11-04 | Uke 15 | 2026 |  |
| 144 | 1.10.5.4.3 | Graveplan |  | 23d | 2026-03-16 | 2026-04-24 | 137SF-5d |  |  |  |  |  | 708d |  | start no earlier than 2026-01-05 | Uke 12 | 2026 |  |
| 145 | 1.10.5.4.4 | Sprengnings- og fyllingsplan |  | 23d | 2026-03-16 | 2026-04-24 | 137SF-5d |  |  |  |  |  | 708d |  |  | Uke 12 | 2026 |  |
| 146 | 1.10.5.4.5 | Spuntplan mot vest og sør |  | 23d | 2026-03-16 | 2026-04-24 | 137SF-5d |  |  |  |  |  | 708d |  | start no earlier than 2026-01-05 | Uke 12 | 2026 |  |
| 147 | 1.10.5.4.6 | Rørvegg not bybane og jernbane |  | 23d | 2026-03-16 | 2026-04-24 | 137SF-5d |  |  |  |  |  | 708d |  |  | Uke 12 | 2026 |  |
| 148 | 1.10.5.4.7 | Peleplan |  | 23d | 2026-03-16 | 2026-04-24 | 137SF-5d |  |  |  |  |  | 708d |  | start no earlier than 2026-01-05 | Uke 12 | 2026 |  |

| ID | WBS | Task | Duration | Start | Finish | Predecessors | Total slack | Free slack | Constraint | Ukenummer | År |
| --- | --- | --- | --- | --- | --- | --- | --- | --- | --- | --- | --- |
| 149 | 1.10.5.5 | **LARK** | 23d | 2026-03-16 | 2026-04-24 |  | 708d |  |  |  |  |
| 150 | 1.10.5.5.1 | LARK-MMI 350-TK-IG 01 | 10d | 2026-03-19 | 2026-04-10 | 151SF | 718d |  | finish no earlier than 2025-11-04 | Uke 12 | 2026 |
| 151 | 1.10.5.5.2 | LARK-MMI 400-AG-IG 01 | 10d | 2026-04-10 | 2026-04-24 | 137SF-5d | 708d | 0d | finish no earlier than 2025-11-04 | Uke 15 | 2026 |
| 152 | 1.10.5.5.3 | Landskapsplan | 23d | 2026-03-16 | 2026-04-24 | 137SF-5d | 708d |  |  | Uke 12 | 2026 |
| 153 | 1.10.5.5.4 | Terrengsnitt | 23d | 2026-03-16 | 2026-04-24 | 137SF-5d | 708d |  |  | Uke 12 | 2026 |
| 154 | 1.10.5.5.5 | Detaljer med overganger inne/ute | 23d | 2026-03-16 | 2026-04-24 | 137SF-5d | 708d |  |  | Uke 12 | 2026 |
| 155 | 1.10.5.5.6 | Tomteteksnisk plan | 23d | 2026-03-16 | 2026-04-24 | 137SF-5d | 708d |  |  | Uke 12 | 2026 |
| 156 | 1.10.5.5.7 | Overvannsplan | 23d | 2026-03-16 | 2026-04-24 | 137SF-5d | 708d |  |  | Uke 12 | 2026 |
| 157 | 1.10.5.6 | **RIB** | 23d | 2026-03-16 | 2026-04-24 |  | 708d |  |  |  |  |
| 158 | 1.10.5.6.1 | RIB-MMI 350-TK-IG 01 | 10d | 2026-03-19 | 2026-04-10 | 159SF | 718d |  | finish no earlier than 2025-11-04 | Uke 12 | 2026 |
| 159 | 1.10.5.6.2 | RIB-MMI 400-AG-IG 01 | 10d | 2026-04-10 | 2026-04-24 | 137SF-5d | 708d | 0d | finish no earlier than 2025-11-04 | Uke 15 | 2026 |
| 160 | 1.10.5.6.3 | Fundamenter pl. U | 23d | 2026-03-16 | 2026-04-24 | 137SF-5d | 708d |  | start no earlier than 2026-01-05 | Uke 12 | 2026 |
| 161 | 1.10.5.6.4 | Fundamenter pl. 01 | 23d | 2026-03-16 | 2026-04-24 | 137SF-5d | 708d |  | start no earlier than 2026-01-05 | Uke 12 | 2026 |
| 162 | 1.10.5.6.5 | Detaljer fundament og pelehode | 23d | 2026-03-16 | 2026-04-24 | 137SF-5d | 708d |  | start no earlier than 2026-01-05 | Uke 12 | 2026 |
| 163 | 1.10.5.6.6 | Spesielle detaljer f.eks. vanntetting | 23d | 2026-03-16 | 2026-04-24 | 137SF-5d | 708d |  |  | Uke 12 | 2026 |
| 164 | 1.10.5.6.7 | VA kulvert | 23d | 2026-03-16 | 2026-04-24 | 137SF-5d | 708d |  |  | Uke 12 | 2026 |
| 165 | 1.10.5.6.8 | Sykkelparkering under terreng | 23d | 2026-03-16 | 2026-04-24 | 137SF-5d | 708d |  |  | Uke 12 | 2026 |
| 166 | 1.10.5.6.9 | Detaljer sammkobling med Kunshøyskole KMD | 23d | 2026-03-16 | 2026-04-24 | 137SF-5d | 708d |  |  | Uke 12 | 2026 |
| 167 | 1.10.5.7 | **ARK** | 23d | 2026-03-16 | 2026-04-24 |  | 708d |  |  |  |  |
| 168 | 1.10.5.7.1 | ARK-MMI 350-TK-IG 01 | 10d | 2026-03-19 | 2026-04-10 | 169SF | 718d |  | finish no earlier than 2025-11-04 | Uke 12 | 2026 |
| 169 | 1.10.5.7.2 | ARK-MMI 400-AG-IG 01 | 10d | 2026-04-10 | 2026-04-24 | 137SF-5d | 708d | 0d | finish no earlier than 2025-11-04 | Uke 15 | 2026 |
| 170 | 1.10.5.7.3 | Plan U. | 23d | 2026-03-16 | 2026-04-24 | 137SF-5d | 708d |  | start no earlier than 2026-01-05 | Uke 12 | 2026 |
| 171 | 1.10.5.7.4 | Plan 01 | 23d | 2026-03-16 | 2026-04-24 | 137SF-5d | 708d |  | start no earlier than 2026-01-05 | Uke 12 | 2026 |
| 172 | 1.10.5.7.5 | Plan 01.5 | 23d | 2026-03-16 | 2026-04-24 | 137SF-5d | 708d |  | start no earlier than 2026-01-05 | Uke 12 | 2026 |
| 173 | 1.10.5.7.6 | Plan 02 | 23d | 2026-03-16 | 2026-04-24 | 137SF-5d | 708d |  | start no earlier than 2026-01-05 | Uke 12 | 2026 |
| 174 | 1.10.5.7.7 | Plan 03 | 23d | 2026-03-16 | 2026-04-24 | 137SF-5d | 708d |  | start no earlier than 2026-01-05 | Uke 12 | 2026 |
| 175 | 1.10.5.7.8 | Plan 04 | 23d | 2026-03-16 | 2026-04-24 | 137SF-5d | 708d |  | start no earlier than 2026-01-05 | Uke 12 | 2026 |
| 176 | 1.10.5.7.9 | Plan 05 | 23d | 2026-03-16 | 2026-04-24 | 137SF-5d | 708d |  | start no earlier than 2026-01-05 | Uke 12 | 2026 |

| ID | WBS | Task | Duration | Start | Finish | Predecessors | Complete | Baseline start | Baseline finish | Baseline duration | Total slack | Free slack | Constraint | Ukenummer | År | Ressurser |
| --- | --- | --- | --- | --- | --- | --- | --- | --- | --- | --- | --- | --- | --- | --- | --- | --- |
| 177 | 1.10.5.8 | **RIVrør** | 23d | 2026-03-16 | 2026-04-24 |  |  |  |  |  | 708d |  |  |  |  |  |
| 178 | 1.10.5.8.1 | RIVrør-MMI 350-TK-IG 01 | 10d | 2026-03-19 | 2026-04-10 | 179SF |  |  |  |  | 718d |  | finish no earlier than 2025-11-04 | Uke 12 | 2026 |  |
| 179 | 1.10.5.8.2 | RIVrør-MMI 400-AG-IG 01 | 10d | 2026-04-10 | 2026-04-24 | 137SF-5d |  |  |  |  | 708d | 0d | finish no earlier than 2025-11-04 | Uke 15 | 2026 |  |
| 180 | 1.10.5.8.3 | Bunnledninger pl. U | 23d | 2026-03-16 | 2026-04-24 | 137SF-5d |  |  |  |  | 708d |  | start no earlier than 2026-01-05 | Uke 12 | 2026 |  |
| 181 | 1.10.5.8.4 | Bunnledninger pl. 1 | 23d | 2026-03-16 | 2026-04-24 | 137SF-5d |  |  |  |  | 708d |  | start no earlier than 2026-01-05 | Uke 12 | 2026 |  |
| 182 | 1.10.5.9 | **RIVVent** | 23d | 2026-03-16 | 2026-04-24 |  |  |  |  |  | 708d |  |  |  |  |  |
| 183 | 1.10.5.9.1 | RIVent-MMI 350-TK-IG 01 | 10d | 2026-03-19 | 2026-04-10 | 184SF |  |  |  |  | 718d |  | finish no earlier than 2025-11-04 | Uke 12 | 2026 |  |
| 184 | 1.10.5.9.2 | RIVent-MMI 400-AG-IG 01 | 10d | 2026-04-10 | 2026-04-24 | 137SF-5d |  |  |  |  | 708d | 0d | finish no earlier than 2025-11-04 | Uke 15 | 2026 |  |
| 185 | 1.10.5.9.3 | Ventilasjon pl. U | 23d | 2026-03-16 | 2026-04-24 | 137SF-5d |  |  |  |  | 708d |  | start no earlier than 2026-01-05 | Uke 12 | 2026 |  |
| 186 | 1.10.5.10 | **RIE** | 23d | 2026-03-16 | 2026-04-24 |  |  |  |  |  | 708d |  |  |  |  |  |
| 187 | 1.10.5.10.1 | RIE-MMI 350-TK-IG 01 | 10d | 2026-03-19 | 2026-04-10 | 188SF |  |  |  |  | 718d |  | finish no earlier than 2025-11-04 | Uke 12 | 2026 |  |
| 188 | 1.10.5.10.2 | RIE-MMI 400-AG-IG 01 | 10d | 2026-04-10 | 2026-04-24 | 137SF-5d |  |  |  |  | 708d | 0d | finish no earlier than 2025-11-04 | Uke 15 | 2026 |  |
| 189 | 1.10.5.10.3 | Basisinstallasjon pl. U | 23d | 2026-03-16 | 2026-04-24 | 137SF-5d |  |  |  |  | 708d |  | start no earlier than 2026-01-05 | Uke 12 | 2026 |  |
| 190 | 1.10.5.11 | Premissfag | 1d? | 2025-09-11 | 2025-09-11 |  |  |  |  |  | 855d |  |  | Uke 37 | 2025 |  |
| 191 | 1.10.6 | Prosjektering for IG 02 | 20d | 2026-05-15 | 2026-06-12 | 135 |  | 2026-02-05 | 2026-03-04 | 20d | 695d | 0d |  | Uke 20 | 2026 |  |
| 192 | 1.10.7 | Videre detaljprosjektering | 6mo | 2026-06-15 | 2026-12-17 | 191 |  | 2026-03-05 | 2026-10-20 | 7mo | 695d |  |  | Uke 25 | 2026 |  |
| 193 | 1.11 | **Riving** | 143d | 2025-09-11 A | 2026-04-16 A |  | 100% |  |  |  |  |  |  | Uke 37 | 2025 |  |
| 194 | 1.11.1 | Fjerne skilt - Pkt 1 | 2d | 2026-04-07 A | 2026-04-08 A |  | 100% |  |  |  |  |  | start no earlier than 2026-04-07 | Uke 15 | 2026 | Veidekke |
| 195 | 1.11.2 | Koble fra adgangskontroll sykkelparkering | 1d | 2026-04-07 A | 2026-04-07 A |  | 100% |  |  |  |  |  | start no earlier than 2026-04-07 | Uke 15 | 2026 | Statsbygg |
| 196 | 1.11.3 | Demontere Elbilladere | 1d | 2026-04-16 A | 2026-04-16 A |  | 100% |  |  |  |  |  | start no earlier than 2026-04-16 | Uke 16 | 2026 | FLM |
| 197 | 1.11.4 | Demontere sykkeskur | 3d | 2026-04-07 A | 2026-04-09 A |  | 100% |  |  |  |  |  | start no earlier than 2026-04-07 | Uke 15 | 2026 | Veidekke |
| 198 | 1.11.5 | Demontere sykkelstativer | 2d | 2026-04-10 A | 2026-04-13 A | 197 | 100% |  |  |  |  |  |  | Uke 15 | 2026 | Veidekke |
| 199 | 1.11.6 | Demontere gitter trafo | 1d | 2026-04-08 A | 2026-04-08 A |  | 100% |  |  |  |  |  | start no earlier than 2026-04-08 | Uke 15 | 2026 | Veidekke |
| 200 | 1.11.7 | Demontere eksisterende rekkverk/byggegjerder | 2d | 2026-04-10 A | 2026-04-13 A |  | 100% |  |  |  |  |  | start no earlier than 2026-04-10 | Uke 15 | 2026 | Veidekke |
| 201 | 1.11.8 | Rive skur | 5d | 2026-04-09 A | 2026-04-15 A | 199 | 100% |  |  |  |  |  |  | Uke 15 | 2026 | Statsbygg |
| 202 | 1.11.9 | Kjernebore føringsvei tavlerom | 1d | 2026-04-16 A | 2026-04-16 A |  | 100% |  |  |  |  |  | start no earlier than 2026-04-16 | Uke 16 | 2026 | BKK |
| 203 | 1.11.10 | Sage støttemur og døråpning | 2d | 2025-09-11 A | 2025-09-12 A |  | 100% |  |  |  |  |  |  | Uke 37 | 2025 | Sørheim? |
| 204 | 1.11.11 | Rive betongvegg | 1d | 2025-09-11 A | 2025-09-11 A |  | 100% |  |  |  |  |  |  | Uke 37 | 2025 | Grunn |

| ID | WBS | Task | Duration | Start | Finish | Predecessors | Complete | Remaining | Baseline start | Baseline finish | Baseline duration | Total slack | Free slack | Constraint | Ukenummer | År | Ressurser | Kontrollplan |
| --- | --- | --- | --- | --- | --- | --- | --- | --- | --- | --- | --- | --- | --- | --- | --- | --- | --- | --- |
| 205 | 1.12 | **Rigg** | 295d? | 2025-09-11 A | 2026-12-09 |  | 49% | 151.42d? | 2025-09-11 | 2026-04-09 | 137d | 701d |  |  | Uke 37 | 2025 |  |  |
| 206 | 1.12.1 | Inngjerding av tomt | 4d | 2026-04-07 A | 2026-04-13 A | 212SF-5d | 100% |  | 2026-03-13 | 2026-03-18 | 3d |  |  | start no earlier than 2026-04-07 | Uke 15 | 2026 | Grunn |  |
| 207 | 1.12.2 | Skogrydding | 3d | 2025-09-11 A | 2025-09-15 A |  | 100% |  |  |  |  |  |  |  | Uke 37 | 2025 | Grunn |  |
| 208 | 1.12.3 | Avgrave og planere ut brakkeunderlag | 3d | 2025-09-11 A | 2025-09-15 A |  | 100% |  |  |  |  |  |  |  | Uke 37 | 2025 | Grunn |  |
| 209 | 1.12.4 | Avgraving jordlag | 5d | 2026-04-15 A | 2026-04-21 A |  | 100% |  |  |  |  |  |  | start no earlier than 2026-04-15 | Uke 16 | 2026 | Grunn |  |
| 210 | 1.12.5 | Etablere byggstrøm | 2d | 2026-04-16 A | 2026-04-17 A |  | 100% |  |  |  |  |  |  | start no earlier than 2026-04-16 | Uke 16 | 2026 | FLM |  |
| 211 | 1.12.6 | Montere byggeplass kamera | 1d | 2026-04-17 A | 2026-04-17 A |  | 100% |  |  |  |  |  |  | start no earlier than 2026-04-17 | Uke 16 | 2026 | Veidekke |  |
| 212 | 1.12.7 | Brakkerigg | 5d | 2026-04-20 A | 2026-04-24 A | 25SF-3w | 100% |  | 2026-03-25 | 2026-04-09 | 5d |  |  | start no earlier than 2026-04-20 | Uke 17 | 2026 | Cramo |  |
| 213 | 1.12.8 | Fjerne asfalt | 5d | 2026-04-22 A | 2026-04-28 | 209 | 75% | 1.25d |  |  |  | 2.7d | 0d |  | Uke 17 | 2026 | Grunn |  |
| 214 | 1.12.9 | Fjerne eksisterende betong elementer | 3d | 2026-04-29 A | 2026-05-04 | 213 | 90% | 0.3d |  |  |  | 842d |  |  | Uke 18 | 2026 | Grunn |  |
| 215 | 1.12.10 | Grøft for tilkobling brakkerigg | 2d | 2026-04-27 A | 2026-04-28 A | 212 | 100% |  |  |  |  |  |  |  | Uke 18 | 2026 | Grunn |  |
| 216 | 1.12.11 | Tilkobling brakkerigg VA rørlegger | 2d | 2026-04-27 A | 2026-04-28 A | 212 | 100% |  |  |  |  |  |  |  | Uke 18 | 2026 | Grevstad og Tvedt |  |
| 217 | 1.12.12 | Demontere lyktestolper | 1d | 2026-04-29 A | 2026-04-29 A | 216 | 100% |  |  |  |  |  |  | start no earlier than 2026-04-17 | Uke 18 | 2026 | Grunn |  |
| 218 | 1.12.13 | Remontere lyktestolper | 3d | 2026-04-30 | 2026-05-05 | 217 |  |  |  |  |  | 841d |  |  | Uke 18 | 2026 | Grunn |  |
| 219 | 1.12.14 | Etablere områdesikring og byggeplassporter | 2d | 2026-05-06 A | 2026-05-07 A | 218 | 100% |  |  |  |  |  |  |  | Uke 19 | 2026 | Grunn |  |
| 220 | 1.12.15 | Etablere byggestrøm nordside | 2d | 2026-05-08 | 2026-05-11 | 219 |  |  |  |  |  | 837d |  |  | Uke 19 | 2026 | Grunn |  |
| 221 | 1.12.16 | Grave frem eks rørspunt | 1d | 2026-05-13 A | 2026-05-13 A |  | 100% |  |  |  |  |  |  | start no earlier than 2026-05-13 | Uke 20 | 2026 | Grunn |  |
| 222 | 1.12.17 | Wiresage eks rørspunt | 1d? | 2026-06-01 | 2026-06-01 |  |  |  |  |  |  | 824d |  | start no earlier than 2026-06-01 | Uke 23 | 2026 | Riving |  |
| 223 | 1.12.18 | Omlegging høyspent i øst | 1d | 2026-06-09 A | 2026-06-09 A | 235SS-4w | 100% |  |  |  |  |  |  | start no earlier than 2026-05-18 | Uke 24 | 2026 | BKK |  |
| 224 | 1.12.19 | Utvidelse brakkerigg | 3d | 2026-10-22 | 2026-10-26 | 244 |  |  | 2025-09-11 | 2025-09-11 | 1d | 733d |  | start no earlier than 2026-08-17 | Uke 43 | 2026 | Cramo | NA |
| 225 | 1.12.20 | Kranfundament i nord | 5d | 2026-08-27 | 2026-09-02 | 237 |  |  |  |  |  | 771d |  |  | Uke 35 | 2026 | Betong |  |
| 226 | 1.12.21 | Krane 1 (MDT 389 i nord) | 10d | 2026-11-02 | 2026-11-13 | 295SS-10d |  |  |  |  |  | 719d |  |  | Uke 45 | 2026 | Kranor |  |
| 227 | 1.12.22 | Kranfundament (gulv på grunn i sør) | 5d | 2026-11-05 | 2026-11-11 | 248FF |  |  |  |  |  | 701d | 0d |  | Uke 45 | 2026 | Betong |  |
| 228 | 1.12.23 | Krane 2 (MDT 289 i sør) | 10d | 2026-11-26 | 2026-12-09 | 227FS+10d |  |  |  |  |  | 701d |  |  | Uke 48 | 2026 | Kranor |  |

| ID | WBS | Task | Duration | Start | Finish | Predecessors | Complete | Remaining | Baseline start | Baseline finish | Baseline duration | Total slack | Free slack | Constraint | Calendar | Ressurser | Kontrollplan | Ukenummer | Tiltak Utførende | År |
| --- | --- | --- | --- | --- | --- | --- | --- | --- | --- | --- | --- | --- | --- | --- | --- | --- | --- | --- | --- | --- |
| 229 | 1.13 | **Grunnarbeider inkl spunt** | 440d? | 2025-09-11 A | 2027-08-18 |  | 7% | 410.97d? | 2026-04-30 | 2027-04-05 | 212d | 556d |  |  |  |  |  |  |  |  |
| 230 | 1.13.1 | Grave for VA i Møllendalsveien | 15d | 2026-07-28 A | 2026-08-17 | 234 | 40% | 9d |  |  |  | 783d | 0d | start no earlier than 2026-06-08 |  | Grunn | Ja | Uke 31 | SJA | 2026 |
| 231 | 1.13.2 | VA i Møllendalsveien | 15d | 2026-07-28 | 2026-08-17 | 230FF |  |  |  |  |  | 783d |  | start no earlier than 2026-06-08 |  | Grevstad og Tvedt | Ja | Uke 31 | SJA | 2026 |
| 232 | 1.13.3 | Grave frem støttemur | 2d | 2026-06-23 A | 2026-06-24 A | 54 | 100% |  |  |  |  |  |  | start no earlier than 2026-06-08 |  | Grunn | Ja | Uke 26 |  | 2026 |
| 233 | 1.13.4 | Rive Støttemur | 3d | 2026-06-25 A | 2026-06-29 A | 232 | 100% |  |  |  |  |  |  |  |  | Sørheim | NA | Uke 26 |  | 2026 |
| 234 | 1.13.5 | Grave ut og Planere hylle for midlertidig VA | 9d | 2026-06-25 A | 2026-07-27 A | 232 | 100% |  |  |  |  |  |  |  |  | Grunn | NA | Uke 26 |  | 2026 |
| 235 | 1.13.6 | Omlegging VA midlertidig | 10d | 2026-07-28 A | 2026-08-10 | 234 | 50% | 5d | 2026-05-08 | 2026-05-15 | 5d | 3d | 0d |  |  | Grevstad og Tvedt |  | Uke 31 |  | 2026 |
| 236 | 1.13.7 | Graving og planering for VA kulvert | 10d | 2026-08-11 A | 2026-08-24 | 235 | 30% | 7d | 2026-05-18 | 2026-06-01 | 10d | 164d | 0d | start no earlier than 2026-06-08 |  | Grunn | Ja | Uke 33 |  | 2026 |
| 237 | 1.13.8 | Prioriterte Peler VA kulvert og kranfundament | 2d | 2026-08-25 | 2026-08-26 | 236 |  |  |  |  |  | 164d | 0d |  |  | Seabroakers | Ja | Uke 35 |  | 2026 |
| 238 | 1.13.9 | Bunnplate VA kulvert | 10d | 2026-08-27 | 2026-09-09 | 237 |  |  |  |  |  | 701d | 0d |  |  | Betong |  | Uke 35 |  | 2026 |
| 239 | 1.13.10 | Vegger VA Kulvert | 15d | 2026-09-03 | 2026-09-23 | 238FS-5d |  |  |  |  |  | 701d | 0d |  |  | Betong |  | Uke 36 |  | 2026 |
| 240 | 1.13.11 | Legge AF og spillvann inn i kulvert | 10d | 2026-09-24 | 2026-10-07 | 239 |  |  |  |  |  | 701d | 0d |  |  | Grevstad og Tvedt |  | Uke 39 |  | 2026 |
| 241 | 1.13.12 | Montere stål VA kulvert | 2d | 2025-09-11 | 2025-09-12 |  |  |  |  |  |  | 994d |  |  |  | Betong |  | Uke 37 |  | 2025 |
| 242 | 1.13.13 | Montere plattendekke ink støp | 5d | 2026-10-08 | 2026-10-14 | 240 |  |  |  |  |  | 701d | 0d |  |  | Betong |  | Uke 41 |  | 2026 |
| 243 | 1.13.14 | Montere fordrøyningsmagasin | 2d | 2026-10-20 | 2026-10-21 | 244FF |  |  |  |  |  | 736d |  |  |  | Grevstad og tvedt |  | Uke 43 |  | 2026 |
| 244 | 1.13.15 | Tilfylling og planering rundt kulvert | 5d | 2026-10-15 | 2026-10-21 | 242 |  |  |  |  |  | 701d | 0d |  |  | Grunn |  | Uke 42 |  | 2026 |
| 245 | 1.13.16 | Planering for sykkelparkering | 5d | 2026-10-22 | 2026-10-28 | 244 |  |  |  |  |  | 701d | 0d |  |  | Grunn |  | Uke 43 |  | 2026 |
| 246 | 1.13.17 | Opi kanal | 5d | 2026-10-22 | 2026-10-28 | 245FF |  |  |  |  |  | 701d | 0d |  |  | Betong |  | Uke 43 |  | 2026 |
| 247 | 1.13.18 | Peler sykkelparkering og Kran | 5d | 2026-10-29 | 2026-11-04 | 246 |  |  |  |  |  | 701d | 0d |  |  | Seabroakers |  | Uke 44 |  | 2026 |
| 248 | 1.13.19 | Støpe bunnplate sykkelparkering | 5d | 2026-11-05 | 2026-11-11 | 247 |  |  |  |  |  | 701d | 0d |  |  | Betong |  | Uke 45 |  | 2026 |
| 249 | 1.13.20 | Planere for rørvegg | 10d | 2026-06-08 | 2026-06-22 | 250SF-5d |  |  |  |  |  | 810d |  | start no earlier than 2026-06-01 |  | Grunn |  | Uke 24 |  | 2026 |
| 250 | 1.13.21 | Rørspunt (Forsere ved arbeid i ferie) | 30d | 2026-06-29 | 2026-08-07 | 54FS+4d |  |  |  |  |  | 0d |  | start no earlier than 2026-06-08 | Rørvegg | Seabroakers | Ja | Uke 27 | SJA | 2026 |
| 251 | 1.13.22 | Senke terreng fremkant rørvegg | 21d | 2026-06-22 A | 2026-08-07 | 252SS-5d | 24% | 16d |  |  |  | 789d |  |  |  | Grunn |  | Uke 26 |  | 2026 |
| 252 | 1.13.23 | Montere puter og stag rørvegg | 20d | 2026-07-27 | 2026-08-21 | 250FS-10d |  |  |  |  |  | 0d |  |  |  | Seabroakers | Ja | Uke 31 |  | 2026 |
| 253 | 1.13.24 | Utstøping rørspunt | 26d | 2026-06-29 A | 2026-08-21 | 252FF | 19% | 21d |  |  |  | 22d | 2d |  |  | Betong | Ja | Uke 27 |  | 2026 |
| 254 | 1.13.25 | Grave ned terrenget til z-spunt | 5d | 2026-08-12 | 2026-08-18 | 253FS-10d |  |  | 2026-04-30 | 2026-05-15 | 10d | 782d |  | start no earlier than 2026-08-12 |  | Grunn | NA | Uke 33 |  | 2026 |
| 255 | 1.13.26 | Z-spunt | 15d | 2026-08-17 | 2026-09-04 | 253FS-10d |  |  |  |  |  | 17d | 0d | start no earlier than 2026-08-17 |  | Seabroakers | Ja | Uke 34 |  | 2026 |
| 256 | 1.13.27 | Senke terreng til puter og stag z-spunt | 5d | 2026-08-31 | 2026-09-04 | 255FF |  |  |  |  |  | 17d | 0d |  |  | Grunn |  | Uke 36 |  | 2026 |
| 257 | 1.13.28 | Stag og puter Z-spunt | 10d | 2026-09-07 | 2026-09-18 | 256 |  |  |  |  |  | 17d | 0d |  |  | Seabroakers | Ja | Uke 37 |  | 2026 |
| 258 | 1.13.29 | Grave ut Byggegrop til UK bunnplate | 10d | 2026-09-21 | 2026-10-02 | 257 |  |  |  |  |  | 17d | 0d |  |  | Grunn | Ja | Uke 39 |  | 2026 |
| 259 | 1.13.30 | Sprenge antatt fjell i Nord/øst | 10d | 2026-10-05 | 2026-10-16 | 258 |  |  |  |  |  | 17d | 0d |  |  | Grunn |  | Uke 41 |  | 2026 |
| 260 | 1.13.31 | Grave ut sprengmasser | 10d | 2026-10-12 | 2026-10-23 | 259FS-5d |  |  |  |  |  | 17d | 0d |  |  | Grunn |  | Uke 42 |  | 2026 |
| 261 | 1.13.32 | Fjellsikring av skjæring | 5d | 2026-10-26 | 2026-10-30 | 260 |  |  |  |  |  | 729d |  |  |  | Grunn |  | Uke 44 |  | 2026 |
| 262 | 1.13.33 | Fjellbolter til bunnplate | 5d | 2026-10-26 | 2026-10-30 | 260 |  |  |  |  |  | 17d | 0d |  |  | Grunn |  | Uke 44 |  | 2026 |
| 263 | 1.13.34 | Planere UK synker | 5d | 2026-11-02 | 2026-11-06 | 262 |  |  |  |  |  | 719d | 0d |  |  | Grunn |  | Uke 45 |  | 2026 |
| 264 | 1.13.35 | Planere UK bunnplate | 10d | 2026-11-02 | 2026-11-13 | 263FS-5d |  |  |  |  |  | 719d |  |  |  | Grunn |  | Uke 45 |  | 2026 |
| 265 | 1.13.36 | Peler U1 | 15d | 2026-11-02 | 2026-11-20 | 262 |  |  |  |  |  | 17d | 0d |  |  | Seabroakers |  | Uke 45 |  | 2026 |
| 266 | 1.13.37 | Tilfylling randbjelke og fundamenter | 5d | 2026-12-07 | 2026-12-11 | 292 |  |  |  |  |  | 699d |  |  |  | Grunn |  | Uke 50 |  | 2026 |
| 267 | 1.13.38 | Tilfylling mot teknisk kulvert ink planering (Forseres ved å stemple vegger) | 10d | 2027-02-03 | 2027-02-16 | 305 |  |  |  |  |  | 52d | 0d |  |  | Grunn |  | Uke 5 |  | 2027 |
| 268 | 1.13.39 | Rørspunt (oppstart ved eksisterende spunt | 30d | 2026-06-23 | 2026-08-21 | 54 |  |  | 2026-05-18 | 2026-06-29 | 30d | 779d | 0d |  |  | Seabroakers | Ja | Uke 26 | SJA | 2026 |
| 269 | 1.13.40 | Omlegging VA (AF,OV) | 10d | 2026-10-06 | 2026-10-19 | 290 |  |  | 2026-08-04 | 2026-08-17 | 10d | 698d | 0d |  |  | Grevstad og Tvedt |  | Uke 41 |  | 2026 |
| 270 | 1.13.41 | Grøfting for utvendig VA mellom GA KHIB | 1d? | 2025-09-11 | 2025-09-11 |  |  |  |  |  |  | 995d |  |  |  | Grunn |  | Uke 37 |  | 2025 |
| 271 | 1.13.42 | Utvendig VA Mellom GA KHIB | 15d | 2026-10-20 | 2026-11-09 | 269 |  |  | 2026-08-18 | 2026-09-07 | 15d | 723d |  |  |  | Grevstad og Tvedt |  | Uke 43 |  | 2026 |
| 272 | 1.13.43 | Avgraving etter rørspunt/klargjøring z-spunt | 5d | 2026-08-17 | 2026-08-21 | 268FS-5d |  |  | 2026-06-23 | 2026-06-29 | 5d | 779d |  |  |  | Grunn | Ja | Uke 34 |  | 2026 |
| 273 | 1.13.44 | Utgraving løsmasser byggegrop | 10d | 2026-09-07 | 2026-09-18 | 255 |  |  | 2026-08-18 | 2026-09-14 | 20d | 719d | 21d |  |  | Grunn |  | Uke 37 |  | 2026 |
| 274 | 1.13.45 | Grøfting Innvending | 5d | 2027-02-17 | 2027-02-23 | 267 |  |  |  |  |  | 644d | 0d |  |  | Grunn |  | Uke 7 |  | 2027 |
| 275 | 1.13.46 | Rør i grunn | 5d | 2027-02-24 | 2027-03-02 | 274 |  |  |  |  |  | 649d |  |  |  | Grevstad og Tvedt |  | Uke 8 |  | 2027 |
| 276 | 1.13.47 | Planering og tilfylling UK fgulv | 5d | 2027-03-17 | 2027-03-31 | 320 |  |  | 2027-01-08 | 2027-01-21 | 10d | 634d |  |  |  | Grunn |  | Uke 11 |  | 2027 |
| 277 | 1.13.48 | Grøfting innvendig | 5d | 2027-02-24 | 2027-03-02 | 274 |  |  |  |  |  | 644d | 0d |  |  | Grunn |  | Uke 8 |  | 2027 |
| 278 | 1.13.49 | Rør i grunn | 5d | 2027-03-03 | 2027-03-09 | 277 |  |  |  |  |  | 644d |  |  |  | Grevstad og Tvedt |  | Uke 9 |  | 2027 |
| 279 | 1.13.50 | Peler Del A (utenfor nålevegg, inkludert kranfundament) | 15d | 2026-08-27 | 2026-09-16 | 237 |  |  | 2026-09-09 | 2026-09-29 | 15d | 164d | 112d |  |  | Seabroakers | Ja | Uke 35 |  | 2026 |
| 280 | 1.13.51 | Peler Del B (innenfor nålevegg) | 10d | 2027-02-17 | 2027-03-02 | 267 |  |  | 2027-01-22 | 2027-02-04 | 10d | 52d | 0d |  |  | Seabroakers |  | Uke 7 |  | 2027 |
| 281 | 1.13.52 | Energibrønner 11stk | 22d | 2027-02-01 | 2027-03-02 | 279FF, 280FF |  |  | 2027-02-05 | 2027-03-08 | 22d | 649d |  |  |  | Grevstad og Tvedt |  | Uke 5 |  | 2027 |
| 282 | 1.13.53 | Tilfylling Del 1 | 10d | 2027-04-26 | 2027-05-10 | 314FS+10d |  |  | 2027-02-23 | 2027-03-08 | 10d | 607d |  |  |  |  |  | Uke 17 |  | 2027 |
| 283 | 1.13.54 | Tilfylling Del 2 | 5d | 2027-04-26 | 2027-04-30 | 314FS+10d |  |  | 2027-02-23 | 2027-03-01 | 5d | 612d |  |  |  |  |  | Uke 17 |  | 2027 |
| 284 | 1.13.55 | Grunnarbeid Møllendalsveien | 2mo | 2026-10-20 | 2026-12-14 | 269, 273 |  |  | 2026-09-15 | 2026-11-09 | 2mo | 698d |  |  |  |  |  | Uke 43 |  | 2026 |
| 285 | 1.13.56 | Trekkerør for fiber eksterne leverandører | 2d | 2027-08-17 | 2027-08-18 | 337 |  |  |  |  |  | 556d |  |  |  |  |  | Uke 33 |  | 2027 |
| 286 | 1.13.57 | Trekkerør for fiber fra BB til GA | 2d | 2027-08-17 | 2027-08-18 | 337 |  |  |  |  |  | 556d |  |  |  | UIB |  | Uke 33 |  | 2027 |
| 287 | 1.13.58 | Trekke fiber fra BB til GA | 2d | 2025-09-11 | 2025-09-12 |  |  |  |  |  |  | 994d |  |  |  | UIB |  | Uke 37 |  | 2025 |
| 288 | 1.13.59 | Legge fjernvarmerør | 2w | 2027-03-03 | 2027-03-16 | 280 |  |  |  |  |  | 639d |  |  |  | Eviny Termo |  | Uke 9 |  | 2027 |

| ID | WBS | Task | Duration | Start | Finish | Predecessors | Baseline start | Baseline finish | Baseline duration | Total slack | Free slack | Ressurser | Kontrollplan | Ukenummer | År |
| --- | --- | --- | --- | --- | --- | --- | --- | --- | --- | --- | --- | --- | --- | --- | --- |
| 289 | 1.14 | **Råbygg** | 230d? | 2026-08-25 | 2027-08-30 |  | 2026-06-02 | 2027-06-09 | 237d? | 43d | 0d |  |  |  |  |
| 290 | 1.14.1 | VA Kulvert | 30d | 2026-08-25 | 2026-10-05 | 236 | 2026-06-02 | 2026-08-03 | 30d | 698d | 0d | Betong | Nei | Uke 35 | 2026 |
| 291 | 1.14.2 | **Plan U1** | 99d? | 2026-11-16 | 2027-04-20 |  | 2026-09-23 | 2027-02-10 | 94d? | 22d |  |  |  | Uke 35 | 2021 |
| 292 | 1.14.2.1 | Randbjelke | 10d | 2026-11-23 | 2026-12-04 | 265 |  |  |  | 17d | 0d | Betong |  | Uke 48 | 2026 |
| 293 | 1.14.2.2 | Punktfundamenter 10stk | 10d | 2026-11-23 | 2026-12-04 | 292SS | 2026-09-30 | 2026-10-06 | 5d | 17d | 0d | Betong |  | Uke 48 | 2026 |
| 294 | 1.14.2.3 | Isolering EPS bunnplate | 5d | 2026-12-07 | 2026-12-11 | 293, 292 | 2026-10-07 | 2026-10-13 | 5d | 17d | 0d | Betong |  | Uke 50 | 2026 |
| 295 | 1.14.2.4 | Synker i bunnplate | 10d | 2026-11-16 | 2026-11-27 | 293SS-5d | 2026-09-23 | 2026-10-06 | 10d | 27d | 0d | Betong |  | Uke 47 | 2026 |
| 296 | 1.14.2.5 | Bunnplate (forseres med støpeskjøt) | 25d | 2026-12-14 | 2027-01-26 | 294, 295 | 2026-10-14 | 2026-11-17 | 25d | 17d | 0d | Betong |  | Uke 51 | 2026 |
| 297 | 1.14.2.6 | Betongsøyler 10 stk | 10d | 2027-01-27 | 2027-02-09 | 296 | 2026-11-18 | 2026-12-01 | 10d | 47d | 0d | Betong |  | Uke 4 | 2027 |
| 298 | 1.14.2.7 | Dragere 2 stk | 1d | 2027-02-10 | 2027-02-10 | 297 | 2026-12-02 | 2026-12-02 | 1d | 663d |  | Montasje |  | Uke 6 | 2027 |
| 299 | 1.14.2.8 | Ståldragere 10stk | 2d | 2027-04-01 | 2027-04-02 | 297, 300, 302, 301 | 2027-01-29 | 2027-02-01 | 2d | 17d | 0d | Montasje |  | Uke 13 | 2027 |
| 300 | 1.14.2.9 | Vegger YV (74m x 4,8m) | 15d | 2027-02-03 | 2027-02-23 | 296, 305 | 2026-11-18 | 2026-12-15 | 20d | 17d | 0d | Betong |  | Uke 5 | 2027 |
| 301 | 1.14.2.10 | Høyvegger YV (63m x 11,2m) | 30d | 2027-01-27 | 2027-03-09 | 296 | 2026-12-16 | 2027-01-28 | 25d | 27d | 10d | Betong |  | Uke 4 | 2027 |
| 302 | 1.14.2.11 | Vegger IV (90m x 4,8m) | 20d | 2027-02-24 | 2027-03-31 | 300 | 2026-12-23 | 2027-01-28 | 20d | 17d | 0d | Betong |  | Uke 8 | 2027 |
| 303 | 1.14.2.12 | Dekke akse BB-BA 230m2 | 1d? | 2027-04-01 | 2027-04-01 | 302 | 2027-01-29 | 2027-01-29 | 1d? | 633d |  | Betong |  | Uke 13 | 2027 |
| 304 | 1.14.2.13 | **Teknisk kulvert** | 27d | 2027-01-13 | 2027-02-18 |  | 2026-11-18 | 2027-01-11 | 32d | 17d |  |  |  | Uke 35 | 2021 |
| 305 | 1.14.2.13.1 | Vegger (72m x 3,5m) (stemples for tilbakefylling) | 15d | 2027-01-13 | 2027-02-02 | 296FS-10d | 2026-11-18 | 2026-12-22 | 25d | 17d | 0d | Betong |  | Uke 2 | 2027 |
| 306 | 1.14.2.13.2 | Dekke | 15d | 2027-01-27 | 2027-02-16 | 305FS-5d | 2026-12-09 | 2027-01-07 | 15d | 657d | 0d | Betong |  | Uke 4 | 2027 |
| 307 | 1.14.2.13.3 | Søyle | 2d | 2027-02-17 | 2027-02-18 | 306 | 2027-01-08 | 2027-01-11 | 2d | 657d |  | Betong |  | Uke 7 | 2027 |
| 308 | 1.14.2.14 | **jno** | 54d | 2027-01-27 | 2027-04-20 |  | 2026-11-18 | 2027-02-10 | 54d | 620d |  |  |  | Uke 47 | 2026 |
| 309 | 1.14.2.14.1 | Sjakt 4 Vareheis | 27d | 2027-01-27 | 2027-03-04 | 296 | 2026-11-18 | 2027-01-04 | 27d | 620d | 0d | Betong |  | Uke 4 | 2027 |
| 310 | 1.14.2.14.2 | Sjakt 3 Trapp | 27d | 2027-03-05 | 2027-04-20 | 309 | 2027-01-05 | 2027-02-10 | 27d | 620d |  | Betong |  | Uke 9 | 2027 |
| 311 | 1.14.2.14.3 | Sjakt 2 Heis og ventilasjon | 27d | 2027-01-27 | 2027-03-04 | 296 | 2026-11-18 | 2027-01-04 | 27d | 647d |  | Betong |  | Uke 4 | 2027 |
| 312 | 1.14.2.14.4 | Sjakt 1 Heis og ventilasjon | 27d | 2027-03-05 | 2027-04-20 | 309 | 2027-01-05 | 2027-02-10 | 27d | 620d |  | Betong |  | Uke 9 | 2027 |

| ID | WBS | Task | Duration | Start | Finish | Predecessors | Baseline start | Baseline finish | Baseline duration | Total slack | Free slack | Ukenummer | År | Ressurser |
| --- | --- | --- | --- | --- | --- | --- | --- | --- | --- | --- | --- | --- | --- | --- |
| 313 | 1.14.3 | **Plan 1** | 101d? | 2026-10-23 | 2027-03-31 |  | 2026-10-23 | 2027-03-31 | 101d? |  |  | Uke 35 | 2021 |  |
| 314 | 1.14.3.1 | Hulldekker 600m2 DOU1 | 5d | 2027-04-05 | 2027-04-09 | 299 | 2027-02-02 | 2027-02-08 | 5d | 17d | 0d | Uke 14 | 2027 | Montasje |
| 315 | 1.14.3.2 | Stålsøyler 5stk | 2d | 2027-04-01 | 2027-04-02 | 302 | 2027-01-29 | 2027-02-01 | 2d | 47d | 30d | Uke 13 | 2027 | Montasje |
| 316 | 1.14.3.3 | Ståldragere 12stk | 2d | 2027-05-19 | 2027-05-20 | 315, 321 | 2027-03-16 | 2027-03-17 | 2d | 17d | 0d | Uke 20 | 2027 | Montasje |
| 317 | 1.14.3.4 | Stripefundament Konsertsal | 10d | 2027-03-03 | 2027-03-16 | 279, 280 | 2026-10-23 | 2026-11-05 | 10d | 609d | 0d | Uke 9 | 2027 | Betong |
| 318 | 1.14.3.5 | Stripefundament Kammersal | 10d | 2027-03-03 | 2027-03-16 | 279, 280 | 2026-10-23 | 2026-11-05 | 10d | 52d | 0d | Uke 9 | 2027 | Betong |
| 319 | 1.14.3.6 | Stripefundament Blackbox | 5d | 2027-03-03 | 2027-03-09 | 280, 279 | 2027-02-05 | 2027-02-11 | 5d | 62d | 0d | Uke 9 | 2027 | Betong |
| 320 | 1.14.3.7 | Punktfundamenter og bjelker(Stålkjernepeler) | 10d | 2027-03-03 | 2027-03-16 | 279, 280 | 2027-02-05 | 2027-02-18 | 10d | 634d | 0d | Uke 9 | 2027 | Betong |
| 321 | 1.14.3.8 | Høyvegger (opptakstudio 44m x 11,2m) | 20d | 2027-04-19 | 2027-05-18 | 314FS+5d | 2027-02-16 | 2027-03-15 | 20d | 17d | 0d | Uke 16 | 2027 | Betong |
| 322 | 1.14.3.9 | Høyvegger Konsertsal (70m x 12,8m) | 30d | 2027-03-17 | 2027-05-05 | 317 | 2026-11-06 | 2026-12-17 | 30d | 609d |  | Uke 11 | 2027 | Betong |
| 323 | 1.14.3.10 | Høyvegger blackbox (55m x 12,8m) | 20d | 2027-03-10 | 2027-04-14 | 319 | 2027-02-12 | 2027-03-11 | 20d | 62d | 0d | Uke 10 | 2027 | Betong |
| 324 | 1.14.3.11 | Høyvegger (Kammersal ink. Lager 65m x 8m) | 30d | 2027-03-17 | 2027-05-05 | 318 | 2026-12-18 | 2027-02-08 | 30d | 52d | 0d | Uke 11 | 2027 | Betong |
| 325 | 1.14.3.12 | Bærestål til plan 1,5 (messanin) | 2d | 2027-04-15 | 2027-04-16 | 323 | 2027-03-12 | 2027-03-15 | 2d | 622d |  | Uke 15 | 2027 | Montasje |
| 326 | 1.14.3.13 | Stålsøyler (til plan 2) | 2d | 2027-04-20 | 2027-04-21 | 340FS-2d | 2027-03-17 | 2027-03-18 | 2d | 62d | 10d | Uke 16 | 2027 | Montasje |
| 327 | 1.14.3.14 | Ståldragere 16 stk (til plan 2) | 2d | 2027-05-07 | 2027-05-10 | 326, 324 | 2027-03-19 | 2027-03-30 | 2d | 52d | 0d | Uke 18 | 2027 | Montasje |
| 328 | 1.14.3.15 | Scenegruber (Konsertsal og blackbox) | 5d | 2027-04-15 | 2027-04-21 | 323 | 2027-03-12 | 2027-03-18 | 5d | 619d |  | Uke 15 | 2027 | Betong |
| 329 | 1.14.3.16 | Gulv på grunn 330m2 | 10d | 2027-04-26 | 2027-05-10 | 314FS+10d | 2027-02-23 | 2027-03-08 | 10d | 548d | 0d | Uke 17 | 2027 | Betong |
| 330 | 1.14.3.17 | YV akse BA+ (28m x 5,3m) | 10d | 2027-05-11 | 2027-05-25 | 329 | 2027-03-09 | 2027-03-30 | 10d | 548d | 0d | Uke 19 | 2027 | Betong |
| 331 | 1.14.3.18 | Veggskiver 3stk (28m x 6,2) | 15d | 2027-05-11 | 2027-06-01 | 330FF+5d | 2027-03-09 | 2027-04-06 | 15d | 548d | 0d | Uke 19 | 2027 | Betong |
| 332 | 1.14.3.19 | YV akse BA ink fund (23m x 6,5m) | 10d | 2027-03-10 | 2027-03-31 | 323FS-20d | 2027-02-12 | 2027-02-25 | 10d | 62d | 0d | Uke 10 | 2027 | Betong |
| 333 | 1.14.3.20 | YV og ringmur akse AA ink fund(14m x 3,8m-0,6m) | 5d | 2027-03-10 | 2027-03-16 | 323FS-20d | 2027-02-12 | 2027-02-18 | 5d | 67d | 5d | Uke 10 | 2027 | Betong |
| 334 | 1.14.3.21 | Vegger lager og sykkelparkering (105m x 3,5m) | 20d | 2027-06-02 | 2027-06-29 | 329, 331 | 2027-04-07 | 2027-05-04 | 20d | 548d | 0d | Uke 22 | 2027 | Betong |
| 335 | 1.14.3.22 | Betong Søyler (2stk) | 3d | 2027-06-30 | 2027-07-02 | 334 | 2027-05-05 | 2027-05-10 | 3d | 548d | 0d | Uke 26 | 2027 | Betong |
| 336 | 1.14.3.23 | Betongdragere | 1d | 2027-08-02 | 2027-08-02 | 335 | 2027-05-11 | 2027-05-11 | 1d | 548d | 0d | Uke 31 | 2027 | Montasje |
| 337 | 1.14.3.24 | Hulldekke over sykkelparkering (320m2) | 10d | 2027-08-03 | 2027-08-16 | 336 | 2027-05-12 | 2027-05-26 | 10d | 548d | 0d | Uke 31 | 2027 | Montasje |

| ID | WBS | Task | Duration | Start | Finish | Predecessors | Baseline start | Baseline finish | Baseline duration | Total slack | Free slack | Ukenummer | År | Ressurser |
| --- | --- | --- | --- | --- | --- | --- | --- | --- | --- | --- | --- | --- | --- | --- |
| 338 | 1.14.4 | **Plan 1,5** | 29d | 2027-04-01 | 2027-05-12 |  | 2027-02-26 | 2027-04-15 | 29d | 62d |  | Uke 43 | 2026 |  |
| 339 | 1.14.4.1 | Dekke Messanin 140m2 | 10d | 2027-04-01 | 2027-04-14 | 323FS-10d, 332, 333 | 2027-02-26 | 2027-03-11 | 10d | 62d | 0d | Uke 13 | 2027 | Betong |
| 340 | 1.14.4.2 | Hulldekker 240m2 ink. tilpasninger | 5d | 2027-04-15 | 2027-04-21 | 339 | 2027-03-12 | 2027-03-18 | 5d | 62d | 0d | Uke 15 | 2027 | Montasje |
| 341 | 1.14.4.3 | Ringmur (28m) | 10d | 2027-04-28 | 2027-05-12 | 342 | 2027-04-02 | 2027-04-15 | 10d | 605d |  | Uke 17 | 2027 | Betong |
| 342 | 1.14.4.4 | Betong søyler (4stk) | 4d | 2027-04-22 | 2027-04-27 | 340 | 2027-03-19 | 2027-04-01 | 4d | 605d | 0d | Uke 16 | 2027 | Betong |
| 343 | 1.14.5 | **Plan 2** | 59d | 2027-05-11 | 2027-08-30 |  | 2027-03-18 | 2027-06-09 | 52d | 24d |  | Uke 43 | 2026 |  |
| 344 | 1.14.5.1 | Tilpassings dekker ca 75m2 | 10d | 2027-05-13 | 2027-05-27 | 347FF | 2027-04-02 | 2027-04-15 | 10d | 595d |  | Uke 19 | 2027 | Betong |
| 345 | 1.14.5.2 | Vegger mot sjakt 2 (9m x 4,8m) | 5d | 2027-05-28 | 2027-06-03 | 346 | 2027-04-02 | 2027-04-08 | 5d | 590d |  | Uke 21 | 2027 | Betong |
| 346 | 1.14.5.3 | Hulldekker 641m2 DOP1 | 5d | 2027-05-21 | 2027-05-27 | 316 | 2027-03-18 | 2027-04-01 | 5d | 17d | 0d | Uke 20 | 2027 | Montasje |
| 347 | 1.14.5.4 | Hulldekker 1509m2 DOP1 | 12d | 2027-05-11 | 2027-05-27 | 327 | 2027-03-31 | 2027-04-15 | 12d | 52d | 0d | Uke 19 | 2027 | Montasje |
| 348 | 1.14.5.5 | Veggskive Akse AI (6m x 4,8) | 3d | 2027-05-28 | 2027-06-01 | 354FS-2d | 2027-04-02 | 2027-04-06 | 3d | 592d |  | Uke 21 | 2027 | Betong |
| 349 | 1.14.5.6 | Veggskive Akse 28 (2m x 4,5m) | 2d | 2027-05-28 | 2027-05-31 | 354FS-2d | 2027-04-02 | 2027-04-05 | 2d | 593d |  | Uke 21 | 2027 | Betong |
| 350 | 1.14.5.7 | Vegger ventilasjonsrom kammersal (16m x 4,2m) | 5d | 2027-05-28 | 2027-06-03 | 347 | 2027-04-16 | 2027-04-22 | 5d | 590d |  | Uke 21 | 2027 | Betong |
| 351 | 1.14.5.8 | Ringmur (16m) | 5d | 2027-05-28 | 2027-06-03 | 346 | 2027-04-02 | 2027-04-08 | 5d | 590d |  | Uke 21 | 2027 | Betong |
| 352 | 1.14.5.9 | Ringmur akse BA (24m) | 5d | 2027-08-17 | 2027-08-23 | 337 | 2027-05-27 | 2027-06-02 | 5d | 548d | 0d | Uke 33 | 2027 | Betong |
| 353 | 1.14.5.10 | Dekke med lysåpninger Akse BA + | 5d | 2027-08-24 | 2027-08-30 | 352 | 2027-06-03 | 2027-06-09 | 5d | 548d |  | Uke 34 | 2027 | Betong |
| 354 | 1.14.5.11 | Stålsøyler 16stk | 2d | 2027-05-28 | 2027-05-31 | 346 | 2027-04-02 | 2027-04-05 | 2d | 17d | 0d | Uke 21 | 2027 | Montasje |
| 355 | 1.14.5.12 | Stålsøyler 15stk | 2d | 2027-05-28 | 2027-05-31 | 347 | 2027-04-16 | 2027-04-19 | 2d | 52d | 0d | Uke 21 | 2027 | Montasje |
| 356 | 1.14.5.13 | Ståldragere 22stk | 2d | 2027-06-01 | 2027-06-02 | 354 | 2027-04-06 | 2027-04-07 | 2d | 17d | 0d | Uke 22 | 2027 | Montasje |
| 357 | 1.14.5.14 | Ståldragere 22stk | 2d | 2027-06-01 | 2027-06-02 | 355 | 2027-04-20 | 2027-04-21 | 2d | 52d | 0d | Uke 22 | 2027 | Montasje |
| 358 | 1.14.6 | **Plan 3** | 25d | 2027-05-27 | 2027-06-30 |  | 2027-04-08 | 2027-05-21 | 30d | 22d |  | Uke 43 | 2026 |  |
| 359 | 1.14.6.1 | Hulldekker (517m2) DOP2 | 5d | 2027-06-03 | 2027-06-09 | 356 | 2027-04-08 | 2027-04-14 | 5d | 17d | 0d | Uke 22 | 2027 | Montasje |
| 360 | 1.14.6.2 | Hulldekker (1192m2) DOP2 | 10d | 2027-06-03 | 2027-06-16 | 357 | 2027-04-22 | 2027-05-05 | 10d | 52d | 0d | Uke 22 | 2027 | Montasje |
| 361 | 1.14.6.3 | Tilpassinger Dekke ca 75m2 | 5d | 2027-05-27 | 2027-06-02 | 356FF, 357FF | 2027-04-15 | 2027-04-21 | 5d | 591d |  | Uke 21 | 2027 | Betong |
| 362 | 1.14.6.4 | Ringmur atrium 43m | 10d | 2027-06-17 | 2027-06-30 | 360 | 2027-05-07 | 2027-05-21 | 10d | 571d |  | Uke 24 | 2027 | Betong |
| 363 | 1.14.6.5 | Veggskive Akse AI (6m x 4,5m) | 2d | 2027-06-10 | 2027-06-11 | 359 | 2027-04-15 | 2027-04-16 | 2d | 582d | 3d | Uke 23 | 2027 | Betong |
| 364 | 1.14.6.6 | Vegger mot sjakt 2 (9m x 4,8m) | 5d | 2027-06-10 | 2027-06-16 | 359 | 2027-04-15 | 2027-04-21 | 5d | 579d | 0d | Uke 23 | 2027 | Betong |
| 365 | 1.14.6.7 | Stålsøyler 20 stk | 2d | 2027-06-10 | 2027-06-11 | 359 | 2027-04-15 | 2027-04-16 | 2d | 582d | 3d | Uke 23 | 2027 | Montasje |
| 366 | 1.14.6.8 | Stålsøyler 40 stk | 5d | 2027-06-17 | 2027-06-23 | 360 | 2027-05-07 | 2027-05-13 | 5d | 558d | 0d | Uke 24 | 2027 | Montasje |
| 367 | 1.14.6.9 | Ståldragere 20stk | 2d | 2027-06-17 | 2027-06-18 | 363, 364, 365 | 2027-04-22 | 2027-04-23 | 2d | 579d |  | Uke 24 | 2027 | Montasje |
| 368 | 1.14.6.10 | Ståldragere 36stk | 3d | 2027-06-24 | 2027-06-28 | 366 | 2027-05-14 | 2027-05-19 | 3d | 558d | 0d | Uke 25 | 2027 | Montasje |

| ID | WBS | Task | Type | Duration | Start | Finish | Predecessors | Baseline start | Baseline finish | Baseline duration | Total slack | Free slack | Ukenummer | År | Ressurser |
| --- | --- | --- | --- | --- | --- | --- | --- | --- | --- | --- | --- | --- | --- | --- | --- |
| 369 | 1.14.7 | **Plan 4** |  | 13d | 2027-06-24 | 2027-08-09 |  | 2027-05-14 | 2027-06-02 | 13d | 561d |  | Uke 43 | 2026 |  |
| 370 | 1.14.7.1 | Hulldekker DOP3 |  | 5d | 2027-06-24 | 2027-06-30 | 366 | 2027-05-14 | 2027-05-21 | 5d | 566d | 0d | Uke 25 | 2027 | Montasje |
| 371 | 1.14.7.2 | Hulldekker DOP3 |  | 10d | 2027-06-29 | 2027-08-09 | 368 | 2027-05-20 | 2027-06-02 | 10d | 558d | 0d | Uke 26 | 2027 | Montasje |
| 372 | 1.14.7.3 | Tilpassinger Dekke ca 75m2 |  | 5d | 2027-08-03 | 2027-08-09 | 371FS-5d | 2027-05-27 | 2027-06-02 | 5d | 563d |  | Uke 31 | 2027 | Betong |
| 373 | 1.14.7.4 | Veggskive Akse AI (6m x 5,2m) |  | 3d | 2027-07-01 | 2027-08-02 | 370 | 2027-05-24 | 2027-05-26 | 3d | 568d |  | Uke 26 | 2027 | Betong |
| 374 | 1.14.7.5 | Vegger mot sjakt 2 (9m x 5,5m) |  | 5d | 2027-07-01 | 2027-08-04 | 370 | 2027-05-24 | 2027-05-28 | 5d | 566d |  | Uke 26 | 2027 | Betong |
| 375 | 1.15 | **Tetthus** |  | 140d | 2027-06-03 | 2028-01-20 |  | 2027-04-15 | 2027-12-03 | 145d | 32d | 0d | Uke 37 | 2025 |  |
| 376 | 1.15.1 | Yttervegg inkl vinduer |  | 15d | 2027-06-03 | 2027-06-24 | 377SF | 2027-04-15 | 2027-04-29 | 10d | 576d | 0d | Uke 22 | 2027 | Tømmer |
| 377 | 1.15.2 | Yttervegg inkl vinduer |  | 15d | 2027-06-24 | 2027-08-11 | 359FS+10d | 2027-04-29 | 2027-05-28 | 20d | 17d | 0d | Uke 25 | 2027 | Tømmer |
| 378 | 1.15.3 | Yttervegg inkl vinduer |  | 15d | 2027-08-12 | 2027-09-01 | 377 | 2027-05-31 | 2027-06-18 | 15d | 17d | 0d | Uke 32 | 2027 | Tømmer |
| 379 | 1.15.4 | Yttervegg inkl vinduer |  | 15d | 2027-08-19 | 2027-09-08 | 378SS+5d | 2027-06-07 | 2027-06-25 | 15d | 17d | 0d | Uke 33 | 2027 | Tømmer |
| 380 | 1.15.5 | Lettak montasje 1600m2 |  | 6d | 2027-09-09 | 2027-09-16 | 379 | 2027-06-28 | 2027-08-02 | 6d | 17d | 0d | Uke 36 | 2027 | Lettak |
| 381 | 1.15.6 | Lettak etterarbeid og takluker |  | 9d | 2027-09-17 | 2027-09-29 | 380 | 2027-08-03 | 2027-08-13 | 9d | 17d | 0d | Uke 37 | 2027 | Taktekker |
| 382 | 1.15.7 | Taktekking Atrium |  | 20d | 2027-06-17 | 2027-08-11 | 360 | 2027-06-14 | 2027-08-06 | 20d | 52d | 35d | Uke 24 | 2027 | Taktekker |
| 383 | 1.15.8 | Provisorisk byggetidstekking (utstikk) |  | 1w | 2027-08-10 | 2027-08-16 | 371 | 2027-08-02 | 2027-08-16 | 2w | 558d |  | Uke 32 | 2027 | Taktekker |
| 384 | 1.15.9 | SLAKK |  | 15d | 2027-09-30 | 2027-10-20 | 379, 382, 381 | 2027-08-16 | 2027-09-10 | 20d | 17d | 0d | Uke 39 | 2027 | VD |
| 385 | 1.15.10 | Tetthus | milestone | 0d | 2027-10-20 | 2027-10-20 | 384 | 2027-09-10 | 2027-09-10 | 0d | 17d | 0d | Uke 42 | 2027 |  |
| 386 | 1.15.11 | Fasade (værhud) |  | 3mo | 2027-10-21 | 2028-01-20 | 385 | 2027-09-13 | 2027-12-03 | 3mo | 331d | 0d | Uke 42 | 2027 |  |
| 387 | 1.15.12 | Curtain wall plan 1 |  | 15d | 2027-08-12 | 2027-09-01 | 377 | 2027-05-31 | 2027-06-18 | 15d | 516d | 0d | Uke 32 | 2027 |  |
| 388 | 1.15.13 | Curtain wall plan 2 |  | 10d | 2027-09-02 | 2027-09-15 | 387 | 2027-06-21 | 2027-07-02 | 10d | 516d | 0d | Uke 35 | 2027 |  |
| 389 | 1.15.14 | Curtain wall plan 3 |  | 10d | 2027-09-16 | 2027-09-29 | 388 | 2027-08-02 | 2027-08-13 | 10d | 516d | 0d | Uke 37 | 2027 |  |
| 390 | 1.15.15 | Curtain wall atrium |  | 10d | 2027-09-30 | 2027-10-13 | 389 | 2027-08-16 | 2027-08-27 | 10d | 516d |  | Uke 39 | 2027 |  |
| 391 | 1.16 | **Innredning** |  | 656d? | 2025-09-11 | 2028-08-04 |  | 2027-08-16 | 2028-07-31 | 215d | 340d |  | Uke 37 | 2025 |  |
| 392 | 1.16.1 | Sjakter VVS |  | 40d | 2027-10-07 | 2027-12-01 | 381FS+1w | 2027-08-23 | 2027-10-15 | 40d | 481d |  | Uke 40 | 2027 |  |

| ID | WBS | Task | Type | Duration | Start | Finish | Predecessors | Baseline start | Baseline finish | Baseline duration | Total slack | Free slack | Ukenummer | År | Ressurser |
| --- | --- | --- | --- | --- | --- | --- | --- | --- | --- | --- | --- | --- | --- | --- | --- |
| 393 | 1.16.2 | **Plan 4** |  | 584d | 2025-09-11 | 2028-03-15 |  | 2027-08-16 | 2028-02-16 | 127d | 412d |  | Uke 37 | 2025 |  |
| 394 | 1.16.2.1 | Støvbinding |  | 2d | 2027-09-23 | 2027-09-24 | 385FS-20d | 2027-08-16 | 2027-08-17 | 2d | 17d | 0d | Uke 38 | 2027 |  |
| 395 | 1.16.2.2 | Hovedføringer VVS over himling |  | 20d | 2027-09-27 | 2027-10-22 | 394 | 2027-08-18 | 2027-09-14 | 20d | 444d | 0d | Uke 39 | 2027 |  |
| 396 | 1.16.2.3 | Hovedføringer Elektro over himling |  | 10d | 2027-10-18 | 2027-10-29 | 395FS-5d | 2027-09-08 | 2027-09-21 | 10d | 504d |  | Uke 42 | 2027 |  |
| 397 | 1.16.2.4 | Gulvstøp |  | 20d | 2027-09-27 | 2027-10-22 | 394 | 2027-09-01 | 2027-09-28 | 20d | 17d | 0d | Uke 39 | 2027 |  |
| 398 | 1.16.2.5 | Gulvvarme |  | 20d | 2027-09-27 | 2027-10-22 | 397FF | 2027-09-01 | 2027-09-28 | 20d | 509d |  | Uke 39 | 2027 |  |
| 399 | 1.16.2.6 | Lys, lyd, bilde og fast inventar |  | 5d | 2025-09-11 | 2025-09-17 |  |  |  |  | 991d |  | Uke 37 | 2025 | UIB |
| 400 | 1.16.2.7 | **Sone A** |  | 97d | 2027-10-11 | 2028-03-01 |  | 2027-09-15 | 2028-02-02 | 95d | 17d |  | Uke 37 | 2025 |  |
| 401 | 1.16.2.7.1 | Vegger 1 side gips |  | 5d | 2027-10-11 | 2027-10-15 | 397FS-10d | 2027-09-15 | 2027-09-21 | 5d | 17d | 0d | Uke 41 | 2027 |  |
| 402 | 1.16.2.7.2 | Tekniske installasjoner i vegger |  | 3d | 2027-10-18 | 2027-10-20 | 401 | 2027-09-22 | 2027-09-24 | 3d | 17d | 0d | Uke 42 | 2027 |  |
| 403 | 1.16.2.7.3 | Vegger lukking |  | 8d | 2027-10-21 | 2027-11-01 | 402 | 2027-09-27 | 2027-10-06 | 8d | 17d | 0d | Uke 42 | 2027 |  |
| 404 | 1.16.2.7.4 | Lydisolerende himling |  | 10d | 2027-11-08 | 2027-11-19 | 403FS+4d | 2027-10-13 | 2027-10-26 | 10d | 17d | 0d | Uke 45 | 2027 |  |
| 405 | 1.16.2.7.5 | Sparkling og maling |  | 8d | 2027-11-29 | 2027-12-08 | 404FS+5d | 2027-11-03 | 2027-11-12 | 8d | 17d | 0d | Uke 48 | 2027 |  |
| 406 | 1.16.2.7.6 | Systemhimling/absoerbenter/gulv |  | 20d | 2027-12-15 | 2028-01-19 | 405FS+4d | 2027-11-19 | 2027-12-16 | 20d | 17d | 0d | Uke 50 | 2027 |  |
| 407 | 1.16.2.7.7 | Komplettering VVS |  | 8d | 2028-01-27 | 2028-02-07 | 406FS+5d | 2028-01-03 | 2028-01-12 | 8d | 19d | 2d | Uke 4 | 2028 |  |
| 408 | 1.16.2.7.8 | Komplettering Elektro |  | 8d | 2028-01-27 | 2028-02-07 | 406FS+5d | 2028-01-03 | 2028-01-12 | 8d | 17d | 0d | Uke 4 | 2028 |  |
| 409 | 1.16.2.7.9 | Lys, lyd, bilde og fast inventar |  | 2d | 2028-02-08 | 2028-02-09 | 408 |  |  |  | 17d | 0d | Uke 6 | 2028 | UIB |
| 410 | 1.16.2.7.10 | Befaring og utbedring MC |  | 15d | 2028-02-10 | 2028-03-01 | 407, 408, 409 | 2028-01-13 | 2028-02-02 | 15d | 17d | 0d | Uke 6 | 2028 |  |
| 411 | 1.16.2.7.11 | MC | milestone | 0d | 2028-03-01 | 2028-03-01 | 410 | 2028-02-02 | 2028-02-02 | 0d | 17d | 0d | Uke 9 | 2028 |  |
| 412 | 1.16.2.8 | **Sone B** |  | 97d | 2027-10-18 | 2028-03-08 |  | 2027-09-22 | 2028-02-09 | 95d | 417d |  | Uke 37 | 2025 |  |
| 413 | 1.16.2.8.1 | Vegger 1 side gips |  | 5d | 2027-10-18 | 2027-10-22 | 397FS-5d | 2027-09-22 | 2027-09-28 | 5d | 417d | 0d | Uke 42 | 2027 |  |
| 414 | 1.16.2.8.2 | Tekniske installasjoner i vegger |  | 3d | 2027-10-25 | 2027-10-27 | 413 | 2027-09-29 | 2027-10-01 | 3d | 417d | 0d | Uke 43 | 2027 |  |
| 415 | 1.16.2.8.3 | Vegger lukking |  | 8d | 2027-10-28 | 2027-11-08 | 414 | 2027-10-04 | 2027-10-13 | 8d | 417d | 0d | Uke 43 | 2027 |  |
| 416 | 1.16.2.8.4 | Lydisolerende himling |  | 10d | 2027-11-15 | 2027-11-26 | 415FS+4d | 2027-10-20 | 2027-11-02 | 10d | 417d | 0d | Uke 46 | 2027 |  |
| 417 | 1.16.2.8.5 | Sparkling og maling |  | 8d | 2027-12-06 | 2027-12-15 | 416FS+5d | 2027-11-10 | 2027-11-19 | 8d | 417d | 0d | Uke 49 | 2027 |  |
| 418 | 1.16.2.8.6 | Systemhimling/absoerbenter/gulv |  | 20d | 2027-12-22 | 2028-01-26 | 417FS+4d | 2027-11-26 | 2027-12-23 | 20d | 417d | 0d | Uke 51 | 2027 |  |
| 419 | 1.16.2.8.7 | Komplettering VVS |  | 8d | 2028-02-03 | 2028-02-14 | 418FS+5d | 2028-01-10 | 2028-01-19 | 8d | 419d | 2d | Uke 5 | 2028 |  |
| 420 | 1.16.2.8.8 | Komplettering Elektro |  | 8d | 2028-02-03 | 2028-02-14 | 418FS+5d | 2028-01-10 | 2028-01-19 | 8d | 417d | 0d | Uke 5 | 2028 |  |
| 421 | 1.16.2.8.9 | Lys, lyd, bilde og fast inventar |  | 2d | 2028-02-15 | 2028-02-16 | 420 |  |  |  | 417d | 0d | Uke 7 | 2028 | UIB |
| 422 | 1.16.2.8.10 | Befaring og utbedring MC |  | 15d | 2028-02-17 | 2028-03-08 | 419, 420, 421 | 2028-01-20 | 2028-02-09 | 15d | 417d | 0d | Uke 7 | 2028 |  |
| 423 | 1.16.2.8.11 | MC | milestone | 0d | 2028-03-08 | 2028-03-08 | 422 | 2028-02-09 | 2028-02-09 | 0d | 417d |  | Uke 10 | 2028 |  |

| ID | WBS | Task | Type | Duration | Start | Finish | Predecessors | Baseline start | Baseline finish | Baseline duration | Total slack | Free slack | Ukenummer | År | Ressurser |
| --- | --- | --- | --- | --- | --- | --- | --- | --- | --- | --- | --- | --- | --- | --- | --- |
| 424 | 1.16.2.9 | **Sone C** |  | 97d | 2027-10-25 | 2028-03-15 |  | 2027-09-29 | 2028-02-16 | 95d | 365d |  | Uke 37 | 2025 |  |
| 425 | 1.16.2.9.1 | Vegger 1 side gips |  | 5d | 2027-10-25 | 2027-10-29 | 397 | 2027-09-29 | 2027-10-05 | 5d | 365d | 0d | Uke 43 | 2027 |  |
| 426 | 1.16.2.9.2 | Tekniske installasjoner i vegger |  | 3d | 2027-11-01 | 2027-11-03 | 425 | 2027-10-06 | 2027-10-08 | 3d | 412d | 0d | Uke 44 | 2027 |  |
| 427 | 1.16.2.9.3 | Vegger lukking |  | 8d | 2027-11-04 | 2027-11-15 | 426 | 2027-10-11 | 2027-10-20 | 8d | 412d | 0d | Uke 44 | 2027 |  |
| 428 | 1.16.2.9.4 | Lydisolerende himling |  | 10d | 2027-11-22 | 2027-12-03 | 427FS+4d | 2027-10-27 | 2027-11-09 | 10d | 412d | 0d | Uke 47 | 2027 |  |
| 429 | 1.16.2.9.5 | Sparkling og maling |  | 8d | 2027-12-13 | 2027-12-22 | 428FS+5d | 2027-11-17 | 2027-11-26 | 8d | 412d | 0d | Uke 50 | 2027 |  |
| 430 | 1.16.2.9.6 | Systemhimling/absoerbenter/gulv |  | 20d | 2028-01-06 | 2028-02-02 | 429FS+4d | 2027-12-03 | 2028-01-07 | 20d | 412d | 0d | Uke 1 | 2028 |  |
| 431 | 1.16.2.9.7 | Komplettering VVS |  | 8d | 2028-02-10 | 2028-02-21 | 430FS+5d | 2028-01-17 | 2028-01-26 | 8d | 414d | 2d | Uke 6 | 2028 |  |
| 432 | 1.16.2.9.8 | Komplettering Elektro |  | 8d | 2028-02-10 | 2028-02-21 | 430FS+5d | 2028-01-17 | 2028-01-26 | 8d | 412d | 0d | Uke 6 | 2028 |  |
| 433 | 1.16.2.9.9 | Lys, lyd, bilde og fast inventar |  | 2d | 2028-02-22 | 2028-02-23 | 432 |  |  |  | 412d | 0d | Uke 8 | 2028 | UIB |
| 434 | 1.16.2.9.10 | Befaring og utbedring MC |  | 15d | 2028-02-24 | 2028-03-15 | 431, 432, 433 | 2028-01-27 | 2028-02-16 | 15d | 412d | 0d | Uke 8 | 2028 |  |
| 435 | 1.16.2.9.11 | MC | milestone | 0d | 2028-03-15 | 2028-03-15 | 434 | 2028-02-16 | 2028-02-16 | 0d | 412d |  | Uke 11 | 2028 |  |
| 436 | 1.16.3 | **Plan 3** |  | 631d? | 2025-09-11 | 2028-06-01 |  | 2027-08-18 | 2028-04-27 | 170d | 365d |  | Uke 37 | 2025 |  |
| 437 | 1.16.3.1 | Støvbinding |  | 2d | 2027-09-27 | 2027-09-28 | 394 | 2027-08-18 | 2027-08-19 | 2d | 523d | 0d | Uke 39 | 2027 |  |
| 438 | 1.16.3.2 | Hovedføringer VVS over himling |  | 20d | 2027-10-25 | 2027-11-19 | 395 | 2027-09-15 | 2027-10-12 | 20d | 444d | 0d | Uke 43 | 2027 |  |
| 439 | 1.16.3.3 | Hovedføringer Elektro over himling |  | 10d | 2027-11-15 | 2027-11-26 | 438FS-5d | 2027-10-06 | 2027-10-19 | 10d | 484d |  | Uke 46 | 2027 |  |
| 440 | 1.16.3.4 | Gulvstøp |  | 20d | 2027-10-25 | 2027-11-19 | 397 | 2027-09-29 | 2027-10-26 | 20d | 483d | 0d | Uke 43 | 2027 |  |
| 441 | 1.16.3.5 | Gulvvarme |  | 20d | 2027-10-25 | 2027-11-19 | 440FF | 2027-09-29 | 2027-10-26 | 20d | 483d | 0d | Uke 43 | 2027 |  |
| 442 | 1.16.3.6 | <Ny aktivitet> |  | 1d? | 2025-09-11 | 2025-09-11 |  |  |  |  | 995d |  | Uke 37 | 2025 |  |
| 443 | 1.16.3.7 | **Sone A** |  | 98d | 2027-11-15 | 2028-04-06 |  | 2027-10-20 | 2028-03-08 | 95d | 365d |  | Uke 37 | 2025 |  |
| 444 | 1.16.3.7.1 | Vegger 1 side gips |  | 5d | 2027-11-15 | 2027-11-19 | 425FS+10d | 2027-10-20 | 2027-10-26 | 5d | 365d | 0d | Uke 46 | 2027 |  |
| 445 | 1.16.3.7.2 | Tekniske installasjoner i vegger |  | 3d | 2027-11-22 | 2027-11-24 | 444 | 2027-10-27 | 2027-10-29 | 3d | 396d | 0d | Uke 47 | 2027 |  |
| 446 | 1.16.3.7.3 | Vegger lukking |  | 8d | 2027-11-25 | 2027-12-06 | 445 | 2027-11-01 | 2027-11-10 | 8d | 396d | 0d | Uke 47 | 2027 |  |
| 447 | 1.16.3.7.4 | Lydisolerende himling |  | 10d | 2027-12-13 | 2028-01-03 | 446FS+4d | 2027-11-17 | 2027-11-30 | 10d | 396d | 0d | Uke 50 | 2027 |  |
| 448 | 1.16.3.7.5 | Sparkling og maling |  | 8d | 2028-01-11 | 2028-01-20 | 447FS+5d | 2027-12-08 | 2027-12-17 | 8d | 396d | 0d | Uke 2 | 2028 |  |
| 449 | 1.16.3.7.6 | Systemhimling/absoerbenter/gulv |  | 20d | 2028-01-27 | 2028-02-23 | 448FS+4d | 2028-01-03 | 2028-01-28 | 20d | 396d | 0d | Uke 4 | 2028 |  |
| 450 | 1.16.3.7.7 | Komplettering VVS |  | 8d | 2028-03-02 | 2028-03-13 | 449FS+5d | 2028-02-07 | 2028-02-16 | 8d | 399d | 3d | Uke 9 | 2028 |  |
| 451 | 1.16.3.7.8 | Komplettering Elektro |  | 8d | 2028-03-02 | 2028-03-13 | 449FS+5d | 2028-02-07 | 2028-02-16 | 8d | 396d | 0d | Uke 9 | 2028 |  |
| 452 | 1.16.3.7.9 | Lys, lyd, bilde og fast inventar |  | 3d | 2028-03-14 | 2028-03-16 | 451 |  |  |  | 396d | 0d | Uke 11 | 2028 |  |
| 453 | 1.16.3.7.10 | Befaring og utbedring MC |  | 15d | 2028-03-17 | 2028-04-06 | 450, 451, 452 | 2028-02-17 | 2028-03-08 | 15d | 396d | 0d | Uke 11 | 2028 |  |
| 454 | 1.16.3.7.11 | MC | milestone | 0d | 2028-04-06 | 2028-04-06 | 453 | 2028-03-08 | 2028-03-08 | 0d | 396d |  | Uke 14 | 2028 |  |

| ID | WBS | Task | Type | Duration | Start | Finish | Predecessors | Baseline start | Baseline finish | Baseline duration | Total slack | Free slack | Ukenummer | År | Ressurser |
| --- | --- | --- | --- | --- | --- | --- | --- | --- | --- | --- | --- | --- | --- | --- | --- |
| 455 | 1.16.3.8 | **Sone B** |  | 98d | 2027-12-06 | 2028-05-08 |  | 2027-11-10 | 2028-03-29 | 95d | 365d |  | Uke 37 | 2025 |  |
| 456 | 1.16.3.8.1 | Vegger 1 side gips |  | 5d | 2027-12-06 | 2027-12-10 | 444FS+10d | 2027-11-10 | 2027-11-16 | 5d | 365d | 0d | Uke 49 | 2027 |  |
| 457 | 1.16.3.8.2 | Tekniske installasjoner i vegger |  | 3d | 2027-12-13 | 2027-12-15 | 456 | 2027-11-17 | 2027-11-19 | 3d | 381d | 0d | Uke 50 | 2027 |  |
| 458 | 1.16.3.8.3 | Vegger lukking |  | 8d | 2027-12-16 | 2028-01-04 | 457 | 2027-11-22 | 2027-12-01 | 8d | 381d | 0d | Uke 50 | 2027 |  |
| 459 | 1.16.3.8.4 | Lydisolerende himling |  | 10d | 2028-01-11 | 2028-01-24 | 458FS+4d | 2027-12-08 | 2027-12-21 | 10d | 381d | 0d | Uke 2 | 2028 |  |
| 460 | 1.16.3.8.5 | Sparkling og maling |  | 8d | 2028-02-01 | 2028-02-10 | 459FS+5d | 2028-01-06 | 2028-01-17 | 8d | 381d | 0d | Uke 5 | 2028 |  |
| 461 | 1.16.3.8.6 | Systemhimling/absoerbenter/gulv |  | 20d | 2028-02-17 | 2028-03-15 | 460FS+4d | 2028-01-24 | 2028-02-18 | 20d | 381d | 0d | Uke 7 | 2028 |  |
| 462 | 1.16.3.8.7 | Komplettering VVS |  | 8d | 2028-03-23 | 2028-04-03 | 461FS+5d | 2028-02-28 | 2028-03-08 | 8d | 384d | 3d | Uke 12 | 2028 |  |
| 463 | 1.16.3.8.8 | Komplettering Elektro |  | 8d | 2028-03-23 | 2028-04-03 | 461FS+5d | 2028-02-28 | 2028-03-08 | 8d | 381d | 0d | Uke 12 | 2028 |  |
| 464 | 1.16.3.8.9 | Lys, lyd, bilde og fast inventar |  | 3d | 2028-04-04 | 2028-04-06 | 463 |  |  |  | 381d | 0d | Uke 14 | 2028 | UIB |
| 465 | 1.16.3.8.10 | Befaring og utbedring MC |  | 15d | 2028-04-07 | 2028-05-08 | 462, 463, 464 | 2028-03-09 | 2028-03-29 | 15d | 381d | 0d | Uke 14 | 2028 |  |
| 466 | 1.16.3.8.11 | MC | milestone | 0d | 2028-05-08 | 2028-05-08 | 465 | 2028-03-29 | 2028-03-29 | 0d | 381d |  | Uke 19 | 2028 |  |
| 467 | 1.16.3.9 | **Sone C** |  | 99d | 2028-01-04 | 2028-06-01 |  | 2027-12-01 | 2028-04-27 | 95d | 365d |  | Uke 37 | 2025 |  |
| 468 | 1.16.3.9.1 | Vegger 1 side gips |  | 5d | 2028-01-04 | 2028-01-10 | 456FS+10d | 2027-12-01 | 2027-12-07 | 5d | 365d | 0d | Uke 1 | 2028 |  |
| 469 | 1.16.3.9.2 | Tekniske installasjoner i vegger |  | 3d | 2028-01-11 | 2028-01-13 | 468 | 2027-12-08 | 2027-12-10 | 3d | 365d | 0d | Uke 2 | 2028 |  |
| 470 | 1.16.3.9.3 | Vegger lukking |  | 8d | 2028-01-14 | 2028-01-25 | 469 | 2027-12-13 | 2027-12-22 | 8d | 365d | 0d | Uke 2 | 2028 |  |
| 471 | 1.16.3.9.4 | Lydisolerende himling |  | 10d | 2028-02-01 | 2028-02-14 | 470FS+4d | 2028-01-06 | 2028-01-19 | 10d | 365d | 0d | Uke 5 | 2028 |  |
| 472 | 1.16.3.9.5 | Sparkling og maling |  | 8d | 2028-02-22 | 2028-03-02 | 471FS+5d | 2028-01-27 | 2028-02-07 | 8d | 365d | 0d | Uke 8 | 2028 |  |
| 473 | 1.16.3.9.6 | Systemhimling/absoerbenter/gulv |  | 20d | 2028-03-09 | 2028-04-05 | 472FS+4d | 2028-02-14 | 2028-03-10 | 20d | 365d | 0d | Uke 10 | 2028 |  |
| 474 | 1.16.3.9.7 | Komplettering VVS |  | 8d | 2028-04-21 | 2028-05-03 | 473FS+5d | 2028-03-20 | 2028-03-29 | 8d | 369d | 4d | Uke 16 | 2028 |  |
| 475 | 1.16.3.9.8 | Komplettering Elektro |  | 8d | 2028-04-21 | 2028-05-03 | 473FS+5d | 2028-03-20 | 2028-03-29 | 8d | 365d | 0d | Uke 16 | 2028 |  |
| 476 | 1.16.3.9.9 | Lys, lyd, bilde og fast inventar |  | 4d | 2028-05-04 | 2028-05-09 | 475 |  |  |  | 365d | 0d | Uke 18 | 2028 | UIB |
| 477 | 1.16.3.9.10 | Befaring og utbedring MC |  | 15d | 2028-05-10 | 2028-06-01 | 474, 475, 476 | 2028-03-30 | 2028-04-27 | 15d | 365d | 0d | Uke 19 | 2028 |  |
| 478 | 1.16.3.9.11 | MC | milestone | 0d | 2028-06-01 | 2028-06-01 | 477 | 2028-04-27 | 2028-04-27 | 0d | 365d |  | Uke 22 | 2028 |  |

| ID | WBS | Task | Type | Duration | Start | Finish | Predecessors | Baseline start | Baseline finish | Baseline duration | Total slack | Free slack | Ukenummer | År | Ressurser |
| --- | --- | --- | --- | --- | --- | --- | --- | --- | --- | --- | --- | --- | --- | --- | --- |
| 479 | 1.16.4 | **Plan 2** |  | 188d? | 2027-09-27 | 2028-08-03 |  | 2027-08-20 | 2028-03-15 | 143d | 93d |  | Uke 37 | 2025 |  |
| 480 | 1.16.4.1 | Støvbinding |  | 2d | 2027-09-29 | 2027-09-30 | 437 | 2027-08-20 | 2027-08-23 | 2d | 523d | 0d | Uke 39 | 2027 |  |
| 481 | 1.16.4.2 | Hovedføringer VVS over himling |  | 20d | 2027-11-22 | 2027-12-17 | 438 | 2027-10-13 | 2027-11-09 | 20d | 444d | 0d | Uke 47 | 2027 |  |
| 482 | 1.16.4.3 | Hovedføringer Elektro over himling |  | 10d | 2027-12-13 | 2028-01-03 | 481FS-5d | 2027-11-03 | 2027-11-16 | 10d | 464d |  | Uke 50 | 2027 |  |
| 483 | 1.16.4.4 | Gulvstøp |  | 10d | 2027-09-27 | 2027-10-08 | 397SS | 2027-10-27 | 2027-11-05 | 8d | 419d | 0d | Uke 39 | 2027 |  |
| 484 | 1.16.4.5 | Gulvvarme |  | 6d | 2027-11-22 | 2027-11-29 | 441 | 2027-10-27 | 2027-11-03 | 6d | 483d |  | Uke 47 | 2027 |  |
| 485 | 1.16.4.6 | **Sone A** |  | 90d | 2027-10-11 | 2028-02-21 |  | 2027-09-15 | 2028-02-02 | 95d | 419d |  | Uke 37 | 2025 |  |
| 486 | 1.16.4.6.1 | Vegger 1 side gips |  | 5d | 2027-10-11 | 2027-10-15 | 483 | 2027-09-15 | 2027-09-21 | 5d | 419d | 0d | Uke 41 | 2027 |  |
| 487 | 1.16.4.6.2 | Tekniske installasjoner i vegger |  | 3d | 2027-10-18 | 2027-10-20 | 486 | 2027-09-22 | 2027-09-24 | 3d | 429d | 0d | Uke 42 | 2027 |  |
| 488 | 1.16.4.6.3 | Vegger lukking |  | 8d | 2027-10-21 | 2027-11-01 | 487 | 2027-09-27 | 2027-10-06 | 8d | 429d | 0d | Uke 42 | 2027 |  |
| 489 | 1.16.4.6.4 | Lydisolerende himling |  | 10d | 2027-11-02 | 2027-11-15 | 488 | 2027-10-13 | 2027-10-26 | 10d | 429d | 0d | Uke 44 | 2027 |  |
| 490 | 1.16.4.6.5 | Sparkling og maling |  | 8d | 2027-11-16 | 2027-11-25 | 489 | 2027-11-03 | 2027-11-12 | 8d | 429d | 0d | Uke 46 | 2027 |  |
| 491 | 1.16.4.6.6 | Systemhimling/absoerbenter/gulv |  | 20d | 2027-11-26 | 2027-12-23 | 490 | 2027-11-19 | 2027-12-16 | 20d | 429d | 0d | Uke 47 | 2027 |  |
| 492 | 1.16.4.6.7 | Komplettering VVS |  | 8d | 2028-01-03 | 2028-01-12 | 491 | 2028-01-03 | 2028-01-12 | 8d | 429d | 0d | Uke 1 | 2028 |  |
| 493 | 1.16.4.6.8 | Komplettering Elektro |  | 8d | 2028-01-13 | 2028-01-24 | 492 | 2028-01-03 | 2028-01-12 | 8d | 429d | 0d | Uke 2 | 2028 |  |
| 494 | 1.16.4.6.9 | Lys, lyd, bilde og fast inventar |  | 5d | 2028-01-25 | 2028-01-31 | 493 |  |  |  | 429d | 0d | Uke 4 | 2028 | UIB |
| 495 | 1.16.4.6.10 | Befaring og utbedring MC |  | 15d | 2028-02-01 | 2028-02-21 | 493, 494 | 2028-01-13 | 2028-02-02 | 15d | 429d | 0d | Uke 5 | 2028 |  |
| 496 | 1.16.4.6.11 | MC | milestone | 0d | 2028-02-21 | 2028-02-21 | 495 | 2028-02-02 | 2028-02-02 | 0d | 429d |  | Uke 8 | 2028 |  |
| 497 | 1.16.4.7 | **Sone B** |  | 90d | 2027-10-18 | 2028-02-28 |  | 2027-10-06 | 2028-02-23 | 95d | 419d |  | Uke 37 | 2025 |  |
| 498 | 1.16.4.7.1 | Vegger 1 side gips |  | 5d | 2027-10-18 | 2027-10-22 | 486 | 2027-10-06 | 2027-10-12 | 5d | 419d | 0d | Uke 42 | 2027 |  |
| 499 | 1.16.4.7.2 | Tekniske installasjoner i vegger |  | 3d | 2027-10-25 | 2027-10-27 | 498 | 2027-10-13 | 2027-10-15 | 3d | 424d | 0d | Uke 43 | 2027 |  |
| 500 | 1.16.4.7.3 | Vegger lukking |  | 8d | 2027-10-28 | 2027-11-08 | 499 | 2027-10-18 | 2027-10-27 | 8d | 424d | 0d | Uke 43 | 2027 |  |
| 501 | 1.16.4.7.4 | Lydisolerende himling |  | 10d | 2027-11-09 | 2027-11-22 | 500 | 2027-11-03 | 2027-11-16 | 10d | 424d | 0d | Uke 45 | 2027 |  |
| 502 | 1.16.4.7.5 | Sparkling og maling |  | 8d | 2027-11-23 | 2027-12-02 | 501 | 2027-11-24 | 2027-12-03 | 8d | 424d | 0d | Uke 47 | 2027 |  |
| 503 | 1.16.4.7.6 | Systemhimling/absoerbenter/gulv |  | 20d | 2027-12-03 | 2028-01-07 | 502 | 2027-12-10 | 2028-01-14 | 20d | 424d | 0d | Uke 48 | 2027 |  |
| 504 | 1.16.4.7.7 | Komplettering VVS |  | 8d | 2028-01-10 | 2028-01-19 | 503 | 2028-01-24 | 2028-02-02 | 8d | 424d | 0d | Uke 2 | 2028 |  |
| 505 | 1.16.4.7.8 | Komplettering Elektro |  | 8d | 2028-01-20 | 2028-01-31 | 504 | 2028-01-24 | 2028-02-02 | 8d | 424d | 0d | Uke 3 | 2028 |  |
| 506 | 1.16.4.7.9 | Lys, lyd, bilde og fast inventar |  | 5d | 2028-02-01 | 2028-02-07 | 505 |  |  |  | 424d | 0d | Uke 5 | 2028 | UIB |
| 507 | 1.16.4.7.10 | Befaring og utbedring MC |  | 15d | 2028-02-08 | 2028-02-28 | 506 | 2028-02-03 | 2028-02-23 | 15d | 424d | 0d | Uke 6 | 2028 |  |
| 508 | 1.16.4.7.11 | MC | milestone | 0d | 2028-02-28 | 2028-02-28 | 507 | 2028-02-23 | 2028-02-23 | 0d | 424d |  | Uke 9 | 2028 |  |

| ID | WBS | Task | Type | Duration | Start | Finish | Predecessors | Baseline start | Baseline finish | Baseline duration | Total slack | Free slack | Ukenummer | År | Ressurser |
| --- | --- | --- | --- | --- | --- | --- | --- | --- | --- | --- | --- | --- | --- | --- | --- |
| 509 | 1.16.4.8 | **Sone C** |  | 95d? | 2028-02-11 | 2028-08-03 |  | 2027-10-27 | 2028-03-15 | 95d |  |  | Uke 37 | 2025 |  |
| 510 | 1.16.4.8.1 | Vegger 1 side gips |  | 5d | 2028-02-11 | 2028-02-17 | 498 | 2027-10-27 | 2027-11-02 | 5d | 346d | 0d | Uke 6 | 2028 |  |
| 511 | 1.16.4.8.2 | Tekniske installasjoner i vegger |  | 3d | 2028-02-18 | 2028-02-22 | 510 | 2027-11-03 | 2027-11-05 | 3d | 346d | 0d | Uke 7 | 2028 |  |
| 512 | 1.16.4.8.3 | Vegger lukking |  | 8d | 2028-02-23 | 2028-03-03 | 511 | 2027-11-08 | 2027-11-17 | 8d | 346d | 0d | Uke 8 | 2028 |  |
| 513 | 1.16.4.8.4 | Lydisolerende himling |  | 10d | 2028-03-06 | 2028-03-17 | 512 | 2027-11-24 | 2027-12-07 | 10d | 346d | 0d | Uke 10 | 2028 |  |
| 514 | 1.16.4.8.5 | Sparkling og maling |  | 8d | 2028-03-20 | 2028-03-29 | 513 | 2027-12-15 | 2028-01-03 | 8d | 346d | 0d | Uke 12 | 2028 |  |
| 515 | 1.16.4.8.6 | Systemhimling/absoerbenter/gulv |  | 20d | 2028-03-30 | 2028-05-05 | 514 | 2028-01-10 | 2028-02-04 | 20d | 346d | 0d | Uke 13 | 2028 |  |
| 516 | 1.16.4.8.7 | Komplettering VVS |  | 8d | 2028-05-08 | 2028-05-18 | 515 | 2028-02-14 | 2028-02-23 | 8d | 346d | 0d | Uke 19 | 2028 |  |
| 517 | 1.16.4.8.8 | Komplettering Elektro |  | 8d | 2028-05-19 | 2028-05-31 | 516 | 2028-02-14 | 2028-02-23 | 8d | 346d | 0d | Uke 20 | 2028 |  |
| 518 | 1.16.4.8.9 | Lys, lyd, bilde og fast inventar |  | 5d | 2028-06-01 | 2028-06-08 | 517 |  |  |  | 346d | 0d | Uke 22 | 2028 | UIB |
| 519 | 1.16.4.8.10 | Befaring og utbedring MC |  | 15d | 2028-06-09 | 2028-06-29 | 518 | 2028-02-24 | 2028-03-15 | 15d | 346d | 0d | Uke 23 | 2028 |  |
| 520 | 1.16.4.8.11 | MC | milestone | 0d | 2028-06-29 | 2028-06-29 | 519 | 2028-03-15 | 2028-03-15 | 0d | 346d |  | Uke 26 | 2028 |  |
| 521 | 1.16.5 | **Plan 1** |  | 656d | 2025-09-11 | 2028-08-04 |  | 2027-08-24 | 2028-07-31 | 209d | 340d |  | Uke 37 | 2025 |  |
| 522 | 1.16.5.1 | Støvbinding |  | 2d | 2027-10-01 | 2027-10-04 | 480 | 2027-08-24 | 2027-08-25 | 2d | 523d |  | Uke 39 | 2027 |  |
| 523 | 1.16.5.2 | Hovedføringer VVS over himling |  | 20d | 2027-12-20 | 2028-01-24 | 481 | 2027-11-10 | 2027-12-07 | 20d | 444d | 0d | Uke 51 | 2027 |  |
| 524 | 1.16.5.3 | Hovedføringer Elektro over himling |  | 10d | 2028-01-18 | 2028-01-31 | 523FS-5d | 2027-12-01 | 2027-12-14 | 10d | 444d |  | Uke 3 | 2028 |  |
| 525 | 1.16.5.4 | Gulv på grunn |  | 20d | 2027-10-21 | 2027-11-17 | 385 | 2027-09-13 | 2027-10-08 | 20d | 346d | 0d | Uke 42 | 2027 |  |
| 526 | 1.16.5.5 | Gulvvarme |  | 20d | 2027-10-21 | 2027-11-17 | 525FF | 2027-09-13 | 2027-10-08 | 20d | 491d |  | Uke 42 | 2027 |  |
| 527 | 1.16.5.6 | **Sone A** |  | 105d | 2027-12-16 | 2028-05-31 |  | 2027-11-17 | 2028-06-02 | 128d | 346d |  | Uke 37 | 2025 |  |
| 528 | 1.16.5.6.1 | Vegger 1 side gips |  | 10d | 2027-12-16 | 2028-01-06 | 525FS+20d | 2027-11-17 | 2027-11-30 | 10d | 346d | 0d | Uke 50 | 2027 |  |
| 529 | 1.16.5.6.2 | Tekniske installasjoner i vegger |  | 5d | 2028-01-07 | 2028-01-13 | 528 | 2027-12-01 | 2027-12-07 | 5d | 366d | 0d | Uke 1 | 2028 |  |
| 530 | 1.16.5.6.3 | Vegger lukking |  | 15d | 2028-01-14 | 2028-02-03 | 529 | 2027-12-08 | 2028-01-05 | 15d | 366d | 0d | Uke 2 | 2028 |  |
| 531 | 1.16.5.6.4 | Lydisolerende himling |  | 15d | 2028-02-04 | 2028-02-24 | 530 | 2028-01-12 | 2028-02-01 | 15d | 366d | 0d | Uke 5 | 2028 |  |
| 532 | 1.16.5.6.5 | Sparkling og maling |  | 10d | 2028-02-25 | 2028-03-09 | 531 | 2028-02-09 | 2028-02-22 | 10d | 366d | 0d | Uke 8 | 2028 |  |
| 533 | 1.16.5.6.6 | Systemhimling/absoerbenter/gulv |  | 25d | 2028-03-10 | 2028-04-21 | 532 | 2028-02-29 | 2028-04-18 | 30d | 366d | 0d | Uke 10 | 2028 |  |
| 534 | 1.16.5.6.7 | Komplettering VVS |  | 10d | 2028-04-24 | 2028-05-08 | 533 | 2028-04-26 | 2028-05-10 | 10d | 366d | 0d | Uke 17 | 2028 |  |
| 535 | 1.16.5.6.8 | Komplettering Elektro |  | 10d | 2028-03-10 | 2028-03-23 | 533SS | 2028-04-26 | 2028-05-10 | 10d | 391d | 25d | Uke 10 | 2028 |  |
| 536 | 1.16.5.6.9 | Befaring og utbedring MC |  | 15d | 2028-05-09 | 2028-05-31 | 534, 535 | 2028-05-11 | 2028-06-02 | 15d | 366d | 0d | Uke 19 | 2028 |  |
| 537 | 1.16.5.6.10 | MC | milestone | 0d | 2028-05-31 | 2028-05-31 | 536 | 2028-06-02 | 2028-06-02 | 0d | 366d |  | Uke 22 | 2028 |  |

| ID | WBS | Task | Type | Duration | Start | Finish | Predecessors | Baseline start | Baseline finish | Baseline duration | Total slack | Free slack | Ukenummer | År | Ressurser |
| --- | --- | --- | --- | --- | --- | --- | --- | --- | --- | --- | --- | --- | --- | --- | --- |
| 538 | 1.16.5.7 | **Sone B (ink plan 1,5)** |  | 105d | 2028-01-07 | 2028-06-15 |  | 2027-12-15 | 2028-07-31 | 128d | 346d |  | Uke 37 | 2025 |  |
| 539 | 1.16.5.7.1 | Vegger 1 side gips |  | 10d | 2028-01-07 | 2028-01-20 | 528 | 2027-12-15 | 2028-01-05 | 10d | 346d | 0d | Uke 1 | 2028 |  |
| 540 | 1.16.5.7.2 | Tekniske installasjoner i vegger |  | 5d | 2028-01-21 | 2028-01-27 | 539 | 2028-01-06 | 2028-01-12 | 5d | 356d | 0d | Uke 3 | 2028 |  |
| 541 | 1.16.5.7.3 | Vegger lukking |  | 15d | 2028-01-28 | 2028-02-17 | 540 | 2028-01-13 | 2028-02-02 | 15d | 356d | 0d | Uke 4 | 2028 |  |
| 542 | 1.16.5.7.4 | Lydisolerende himling |  | 15d | 2028-02-18 | 2028-03-09 | 541 | 2028-02-09 | 2028-02-29 | 15d | 356d | 0d | Uke 7 | 2028 |  |
| 543 | 1.16.5.7.5 | Sparkling og maling |  | 10d | 2028-03-10 | 2028-03-23 | 542 | 2028-03-08 | 2028-03-21 | 10d | 356d | 0d | Uke 10 | 2028 |  |
| 544 | 1.16.5.7.6 | Systemhimling/absoerbenter/gulv |  | 25d | 2028-03-24 | 2028-05-08 | 543 | 2028-03-28 | 2028-05-18 | 30d | 356d | 0d | Uke 12 | 2028 |  |
| 545 | 1.16.5.7.7 | Komplettering VVS |  | 10d | 2028-05-09 | 2028-05-23 | 544 | 2028-05-29 | 2028-06-12 | 10d | 356d | 0d | Uke 19 | 2028 |  |
| 546 | 1.16.5.7.8 | Komplettering Elektro |  | 10d | 2028-03-24 | 2028-04-06 | 544SS | 2028-05-29 | 2028-06-12 | 10d | 381d | 25d | Uke 12 | 2028 |  |
| 547 | 1.16.5.7.9 | Befaring og utbedring MC |  | 15d | 2028-05-24 | 2028-06-15 | 545, 546 | 2028-06-13 | 2028-07-31 | 15d | 356d | 0d | Uke 21 | 2028 |  |
| 548 | 1.16.5.7.10 | MC | milestone | 0d | 2028-06-15 | 2028-06-15 | 547 | 2028-07-31 | 2028-07-31 | 0d | 356d |  | Uke 24 | 2028 |  |
| 549 | 1.16.5.8 | maskinrom, redigeringsrom, |  | 6.5mo | 2027-11-11 | 2028-05-31 | 555 | 2027-09-20 | 2027-12-10 | 3mo | 366d | 0d | Uke 45 | 2027 |  |
| 550 | 1.16.5.9 | **Sone C** |  | 105d | 2028-01-21 | 2028-06-29 |  |  |  |  | 346d |  | Uke 37 | 2025 |  |
| 551 | 1.16.5.9.1 | Sone C |  | 105d | 2028-01-21 | 2028-06-29 | 539 |  |  |  | 346d |  | Uke 3 | 2028 |  |
| 552 | 1.16.5.10 | **Konsertsal** |  | 656d | 2025-09-11 | 2028-08-04 |  | 2027-09-13 | 2028-06-19 | 185d | 340d |  | Uke 37 | 2025 |  |
| 553 | 1.16.5.10.1 | Støvbinding |  | 5d | 2027-10-21 | 2027-10-27 | 385 | 2027-09-13 | 2027-09-17 | 5d | 340d | 0d | Uke 42 | 2027 |  |
| 554 | 1.16.5.10.2 | Undermaskineri mekanisk |  | 7d | 2027-10-28 | 2027-11-05 | 553 |  |  |  | 499d |  | Uke 43 | 2027 | UIB |
| 555 | 1.16.5.10.3 | Opphengsystem Sceneteknisk |  | 10d | 2027-10-28 | 2027-11-10 | 553 | 2027-09-20 | 2027-10-01 | 10d | 340d | 0d | Uke 43 | 2027 |  |
| 556 | 1.16.5.10.4 | Tekniske over himling |  | 10d | 2027-11-11 | 2027-11-24 | 555 | 2027-10-04 | 2027-10-15 | 10d | 340d | 0d | Uke 45 | 2027 |  |
| 557 | 1.16.5.10.5 | Påforing vegger |  | 15d | 2027-11-25 | 2027-12-15 | 556 | 2027-10-18 | 2027-11-05 | 15d | 340d | 0d | Uke 47 | 2027 |  |
| 558 | 1.16.5.10.6 | Lydhimling |  | 20d | 2027-12-16 | 2028-01-20 | 557 | 2027-11-08 | 2027-12-03 | 20d | 340d | 0d | Uke 50 | 2027 |  |
| 559 | 1.16.5.10.7 | Opphengssystem tepper |  | 2d | 2025-09-11 | 2025-09-12 |  |  |  |  | 994d |  | Uke 37 | 2025 | UIB |
| 560 | 1.16.5.10.8 | Lydgulv |  | 15d | 2028-01-21 | 2028-02-10 | 558 | 2027-12-06 | 2028-01-03 | 15d | 340d | 0d | Uke 3 | 2028 |  |
| 561 | 1.16.5.10.9 | Akustisk regulerende vegg |  | 20d | 2028-02-11 | 2028-03-09 | 560 | 2028-01-04 | 2028-01-31 | 20d | 340d | 0d | Uke 6 | 2028 |  |
| 562 | 1.16.5.10.10 | Tekniske føringer og bokser i akustisk regulerende vegg |  | 10d | 2028-03-10 | 2028-03-23 | 561 | 2028-02-01 | 2028-02-14 | 10d | 340d | 0d | Uke 10 | 2028 |  |
| 563 | 1.16.5.10.11 | Tilluftkammer integrert i vegg |  | 20d | 2028-03-10 | 2028-04-06 | 562SS | 2028-02-01 | 2028-02-28 | 20d | 340d | 0d | Uke 10 | 2028 |  |
| 564 | 1.16.5.10.12 | Overmaskineri |  | 5d | 2028-04-07 | 2028-04-21 | 563 |  |  |  | 340d | 0d | Uke 14 | 2028 | UIB |
| 565 | 1.16.5.10.13 | Komplettering VVS |  | 10d | 2028-04-24 | 2028-05-08 | 564 | 2028-03-21 | 2028-04-03 | 10d | 340d | 0d | Uke 17 | 2028 |  |
| 566 | 1.16.5.10.14 | Komplettering Elektro |  | 10d | 2028-05-09 | 2028-05-23 | 565 | 2028-03-21 | 2028-04-03 | 10d | 340d | 0d | Uke 19 | 2028 |  |
| 567 | 1.16.5.10.15 | Komplitering undermaskineri |  | 5d | 2028-05-24 | 2028-05-31 | 566 | 2028-04-04 | 2028-04-25 | 10d | 366d |  | Uke 21 | 2028 | UIB |
| 568 | 1.16.5.10.16 | Lys, lyd, bilde og fast inventar |  | 5d | 2028-05-24 | 2028-05-31 | 566 | 2028-04-04 | 2028-04-25 | 10d | 340d | 0d | Uke 21 | 2028 | UIB |
| 569 | 1.16.5.10.17 | Gulvoverflate |  | 15d | 2028-06-01 | 2028-06-22 | 568 | 2028-02-29 | 2028-03-20 | 15d | 340d | 0d | Uke 22 | 2028 |  |
| 570 | 1.16.5.10.18 | Befaring og utbedring MC |  | 10d | 2028-06-23 | 2028-08-03 | 569 | 2028-04-26 | 2028-05-10 | 10d | 340d | 0d | Uke 25 | 2028 |  |
| 571 | 1.16.5.10.19 | SLAKK |  | 1d | 2028-08-04 | 2028-08-04 | 570 | 2028-05-11 | 2028-06-12 | 20d | 340d | 0d | Uke 31 | 2028 |  |
| 572 | 1.16.5.10.20 | MC | milestone | 0d | 2028-08-04 | 2028-08-04 | 571, 593, 610, 626 | 2028-06-19 | 2028-06-19 | 0d | 340d |  | Uke 31 | 2028 |  |

| ID | WBS | Task | Type | Duration | Start | Finish | Predecessors | Baseline start | Baseline finish | Baseline duration | Total slack | Free slack | Ukenummer | År | Ressurser |
| --- | --- | --- | --- | --- | --- | --- | --- | --- | --- | --- | --- | --- | --- | --- | --- |
| 573 | 1.16.5.11 | **Blackboks** |  | 171d | 2027-10-21 | 2028-08-04 |  | 2027-09-13 | 2028-06-19 | 185d | 340d |  | Uke 37 | 2025 |  |
| 574 | 1.16.5.11.1 | Støvbinding |  | 5d | 2027-10-21 | 2027-10-27 | 385 | 2027-09-13 | 2027-09-17 | 5d | 498d | 0d | Uke 42 | 2027 |  |
| 575 | 1.16.5.11.2 | Undermaskineri mekanisk |  | 8d | 2027-10-28 | 2027-11-08 | 574 |  |  |  | 498d |  | Uke 43 | 2027 | UIB |
| 576 | 1.16.5.11.3 | Opphengsystem Sceneteknisk |  | 10d | 2027-11-11 | 2027-11-24 | 555 | 2027-10-04 | 2027-10-15 | 10d | 486d |  | Uke 45 | 2027 |  |
| 577 | 1.16.5.11.4 | Tekniske over himling |  | 10d | 2027-11-25 | 2027-12-08 | 556 | 2027-10-18 | 2027-10-29 | 10d | 340d | 0d | Uke 47 | 2027 |  |
| 578 | 1.16.5.11.5 | Påforing vegger |  | 15d | 2027-12-09 | 2028-01-06 | 577 | 2027-11-01 | 2027-11-19 | 15d | 340d | 0d | Uke 49 | 2027 |  |
| 579 | 1.16.5.11.6 | Tekniske føringer og bokser i akustisk regulerende vegg |  | 10d | 2028-03-03 | 2028-03-16 | 584 | 2028-01-25 | 2028-02-07 | 10d | 340d | 0d | Uke 9 | 2028 |  |
| 580 | 1.16.5.11.7 | Føringer til klanganlegg |  | 10d | 2028-03-03 | 2028-03-16 | 584 |  |  |  | 411d |  | Uke 9 | 2028 |  |
| 581 | 1.16.5.11.8 | Lydhimling |  | 15d | 2028-01-07 | 2028-01-27 | 578 | 2027-11-22 | 2027-12-10 | 15d | 340d | 0d | Uke 1 | 2028 |  |
| 582 | 1.16.5.11.9 | Lydgulv |  | 10d | 2028-01-28 | 2028-02-10 | 581 | 2027-12-13 | 2028-01-03 | 10d | 340d | 0d | Uke 4 | 2028 |  |
| 583 | 1.16.5.11.10 | Klanganlegg |  | 15d | 2028-02-11 | 2028-03-02 | 582 |  |  |  | 421d |  | Uke 6 | 2028 | UIB |
| 584 | 1.16.5.11.11 | Akustisk regulerende vegg |  | 15d | 2028-02-11 | 2028-03-02 | 582 | 2028-01-04 | 2028-01-24 | 15d | 340d | 0d | Uke 6 | 2028 |  |
| 585 | 1.16.5.11.12 | Tilluftkammer integrert i vegg |  | 20d | 2028-03-17 | 2028-04-21 | 579 | 2028-02-08 | 2028-03-06 | 20d | 340d | 0d | Uke 11 | 2028 |  |
| 586 | 1.16.5.11.13 | Overmaskineri |  | 5d | 2028-04-24 | 2028-04-28 | 585 |  |  |  | 340d | 0d | Uke 17 | 2028 | UIB |
| 587 | 1.16.5.11.14 | Komplettering VVS |  | 15d | 2028-05-02 | 2028-05-23 | 586 | 2028-03-28 | 2028-04-25 | 15d | 340d | 0d | Uke 18 | 2028 |  |
| 588 | 1.16.5.11.15 | Komplettering Elektro |  | 10d | 2028-05-24 | 2028-06-08 | 587 | 2028-03-28 | 2028-04-18 | 10d | 340d | 0d | Uke 21 | 2028 |  |
| 589 | 1.16.5.11.16 | Lys, lyd, bilde og fast inventar |  | 5d | 2028-06-09 | 2028-06-15 | 588 | 2028-04-19 | 2028-05-03 | 10d | 340d | 0d | Uke 23 | 2028 | UIB |
| 590 | 1.16.5.11.17 | Undermaskineri Komplettering |  | 5d | 2028-06-09 | 2028-06-15 | 589SS | 2028-04-19 | 2028-05-03 | 10d | 341d | 0d | Uke 23 | 2028 | UIB |
| 591 | 1.16.5.11.18 | Gulvoverflate |  | 15d | 2028-06-16 | 2028-08-03 | 590 | 2028-03-07 | 2028-03-27 | 15d | 341d |  | Uke 24 | 2028 |  |
| 592 | 1.16.5.11.19 | Befaring og utbedring MC |  | 10d | 2028-06-16 | 2028-06-29 | 589 | 2028-05-04 | 2028-05-18 | 10d | 340d | 0d | Uke 24 | 2028 |  |
| 593 | 1.16.5.11.20 | SLAKK |  | 6d | 2028-06-30 | 2028-08-04 | 592 | 2028-05-19 | 2028-06-19 | 20d | 340d | 0d | Uke 26 | 2028 |  |
| 594 | 1.16.5.11.21 | MC | milestone | 0d | 2028-08-04 | 2028-08-04 | 593 | 2028-06-19 | 2028-06-19 | 0d | 340d |  | Uke 31 | 2028 |  |
| 595 | 1.16.5.12 | **Kammersal** |  | 630d | 2025-09-11 | 2028-05-31 |  | 2027-09-13 | 2028-05-03 | 155d | 366d |  | Uke 37 | 2025 |  |
| 596 | 1.16.5.12.1 | Støvbinding |  | 5d | 2027-10-21 | 2027-10-27 | 385 | 2027-09-13 | 2027-09-17 | 5d | 506d | 0d | Uke 42 | 2027 |  |
| 597 | 1.16.5.12.2 | Tekniske over himling |  | 10d | 2027-11-11 | 2027-11-24 | 556SS | 2027-10-04 | 2027-10-15 | 10d | 340d | 0d | Uke 45 | 2027 |  |
| 598 | 1.16.5.12.3 | Påforing vegger |  | 15d | 2027-11-25 | 2027-12-15 | 597 | 2027-10-18 | 2027-11-05 | 15d | 366d | 0d | Uke 47 | 2027 |  |
| 599 | 1.16.5.12.4 | Opphengsystem Tepper |  | 1d | 2025-09-11 | 2025-09-11 |  |  |  |  | 995d |  | Uke 37 | 2025 | UIB |
| 600 | 1.16.5.12.5 | Lydhimling |  | 15d | 2027-12-16 | 2028-01-13 | 598 | 2027-11-08 | 2027-11-26 | 15d | 366d | 0d | Uke 50 | 2027 |  |
| 601 | 1.16.5.12.6 | Lydgulv |  | 10d | 2028-01-14 | 2028-01-27 | 600 | 2027-11-29 | 2027-12-10 | 10d | 366d | 0d | Uke 2 | 2028 |  |
| 602 | 1.16.5.12.7 | Akustisk regulerende vegg |  | 15d | 2028-01-28 | 2028-02-17 | 601 | 2027-12-13 | 2028-01-10 | 15d | 366d | 0d | Uke 4 | 2028 |  |
| 603 | 1.16.5.12.8 | Tekniske føringer og bokser i akustisk regulerende vegg |  | 10d | 2028-02-18 | 2028-03-02 | 602 | 2028-01-11 | 2028-01-24 | 10d | 366d | 0d | Uke 7 | 2028 |  |
| 604 | 1.16.5.12.9 | Overmaskineri |  | 5d | 2028-03-03 | 2028-03-09 | 603 |  |  |  | 366d | 0d | Uke 9 | 2028 | UIB |
| 605 | 1.16.5.12.10 | Komplettering VVS |  | 10d | 2028-03-10 | 2028-03-23 | 604 | 2028-02-15 | 2028-02-28 | 10d | 366d | 0d | Uke 10 | 2028 |  |
| 606 | 1.16.5.12.11 | Komplettering Elektro |  | 10d | 2028-03-10 | 2028-03-23 | 605SS | 2028-02-15 | 2028-02-28 | 10d | 366d | 0d | Uke 10 | 2028 |  |
| 607 | 1.16.5.12.12 | Lys, lyd, bilde og fast inventar |  | 10d | 2028-03-24 | 2028-04-06 | 606 | 2028-02-29 | 2028-03-13 | 10d | 366d | 0d | Uke 12 | 2028 | UIB |
| 608 | 1.16.5.12.13 | Gulvoverflate |  | 15d | 2028-04-07 | 2028-05-08 | 607 | 2028-01-25 | 2028-02-14 | 15d | 381d |  | Uke 14 | 2028 |  |
| 609 | 1.16.5.12.14 | Befaring og utbedring MC |  | 10d | 2028-04-07 | 2028-04-28 | 607 | 2028-03-14 | 2028-03-27 | 10d | 366d | 0d | Uke 14 | 2028 |  |
| 610 | 1.16.5.12.15 | SLAKK |  | 20d | 2028-05-02 | 2028-05-31 | 609 | 2028-03-28 | 2028-05-03 | 20d | 366d | 0d | Uke 18 | 2028 |  |
| 611 | 1.16.5.12.16 | MC | milestone | 0d | 2028-05-31 | 2028-05-31 | 610 | 2028-05-03 | 2028-05-03 | 0d | 366d |  | Uke 22 | 2028 |  |

| ID | WBS | Task | Type | Duration | Start | Finish | Predecessors | Baseline start | Baseline finish | Baseline duration | Total slack | Free slack | Constraint | Ukenummer | År | Ressurser |
| --- | --- | --- | --- | --- | --- | --- | --- | --- | --- | --- | --- | --- | --- | --- | --- | --- |
| 612 | 1.16.5.13 | **Opptakstudio** |  | 656d | 2025-09-11 | 2028-08-04 |  | 2027-09-13 | 2028-06-02 | 175d | 340d |  |  | Uke 37 | 2025 |  |
| 613 | 1.16.5.13.1 | Støvbinding |  | 5d | 2027-10-21 | 2027-10-27 | 385 | 2027-09-13 | 2027-09-17 | 5d | 506d |  |  | Uke 42 | 2027 |  |
| 614 | 1.16.5.13.2 | Tekniske over himling |  | 10d | 2027-11-25 | 2027-12-08 | 597 | 2027-10-18 | 2027-10-29 | 10d | 340d | 0d |  | Uke 47 | 2027 |  |
| 615 | 1.16.5.13.3 | Påforing vegger |  | 15d | 2027-12-09 | 2028-01-06 | 614 | 2027-11-01 | 2027-11-19 | 15d | 340d | 0d |  | Uke 49 | 2027 |  |
| 616 | 1.16.5.13.4 | Opphengsystem Tepper |  | 2d | 2025-09-11 | 2025-09-12 |  |  |  |  | 994d |  |  | Uke 37 | 2025 | UIB |
| 617 | 1.16.5.13.5 | Lydhimling |  | 15d | 2028-01-07 | 2028-01-27 | 615 | 2027-11-22 | 2027-12-10 | 15d | 340d | 0d |  | Uke 1 | 2028 |  |
| 618 | 1.16.5.13.6 | Lydgulv |  | 10d | 2028-01-28 | 2028-02-10 | 617 | 2027-12-13 | 2028-01-03 | 10d | 340d | 0d |  | Uke 4 | 2028 |  |
| 619 | 1.16.5.13.7 | Akustisk regulerende vegg |  | 15d | 2028-02-11 | 2028-03-02 | 618 | 2028-01-04 | 2028-01-24 | 15d | 340d | 0d |  | Uke 6 | 2028 |  |
| 620 | 1.16.5.13.8 | Tekniske føringer og bokser i akustisk regulerende vegg |  | 10d | 2028-03-03 | 2028-03-16 | 619 | 2028-01-25 | 2028-02-07 | 10d | 340d | 0d |  | Uke 9 | 2028 |  |
| 621 | 1.16.5.13.9 | Gulvoverflate |  | 15d | 2028-03-17 | 2028-04-06 | 620 | 2028-02-08 | 2028-02-28 | 15d | 340d | 0d |  | Uke 11 | 2028 |  |
| 622 | 1.16.5.13.10 | Komplettering VVS |  | 10d | 2028-04-07 | 2028-04-28 | 621 | 2028-02-29 | 2028-03-13 | 10d | 340d | 0d |  | Uke 14 | 2028 |  |
| 623 | 1.16.5.13.11 | Komplettering Elektro |  | 10d | 2028-05-02 | 2028-05-15 | 622 | 2028-03-14 | 2028-03-27 | 10d | 340d | 0d |  | Uke 18 | 2028 |  |
| 624 | 1.16.5.13.12 | Lys, lyd, bilde og fast inventar |  | 10d | 2028-05-16 | 2028-05-31 | 623 | 2028-03-28 | 2028-04-18 | 10d | 340d | 0d |  | Uke 20 | 2028 | UIB |
| 625 | 1.16.5.13.13 | Befaring og utbedring MC |  | 10d | 2028-06-01 | 2028-06-15 | 624 | 2028-04-19 | 2028-05-03 | 10d | 340d | 0d |  | Uke 22 | 2028 |  |
| 626 | 1.16.5.13.14 | SLAKK |  | 16d | 2028-06-16 | 2028-08-04 | 625 | 2028-05-04 | 2028-06-02 | 20d | 340d | 0d |  | Uke 24 | 2028 |  |
| 627 | 1.16.5.13.15 | MC | milestone | 0d | 2028-08-04 | 2028-08-04 | 626 | 2028-06-02 | 2028-06-02 | 0d | 340d |  |  | Uke 31 | 2028 |  |
| 628 | 1.16.5.13.16 | Kjøkken |  | 2mo | 2027-11-18 | 2028-01-20 | 525 | 2027-10-11 | 2027-12-03 | 2mo | 451d |  |  | Uke 46 | 2027 |  |
| 629 | 1.16.6 | **Plan U** |  | 100d | 2027-10-21 | 2028-03-16 |  | 2027-09-13 | 2028-02-07 | 100d | 411d |  |  | Uke 37 | 2025 |  |
| 630 | 1.16.6.1 | Varmesentral |  | 5mo | 2027-10-21 | 2028-03-16 | 385 | 2027-09-13 | 2028-02-07 | 5mo | 411d | 0d |  | Uke 42 | 2027 |  |
| 631 | 1.16.6.2 | Hovedtavle |  | 2mo | 2027-10-21 | 2027-12-15 | 385 |  |  |  | 471d | 0d |  | Uke 42 | 2027 |  |
| 632 | 1.17 | Takhager, terrasser |  | 30d | 2028-06-23 | 2028-08-31 | 385FS+8mo | 2028-05-11 | 2028-06-26 | 30d | 321d |  |  | Uke 25 | 2028 |  |
| 633 | 1.18 | **Utomhus** |  | 155d | 2027-12-02 | 2028-08-24 |  | 2027-10-25 | 2028-08-24 | 183d | 326d |  |  | Uke 37 | 2025 |  |
| 634 | 1.18.1 | Betongarbeider utomhus |  | 3mo | 2027-12-02 | 2028-03-02 | 386FS-6w | 2027-10-25 | 2028-01-24 | 3mo | 331d | 0d |  | Uke 48 | 2027 |  |
| 635 | 1.18.2 | Anleggsgartnerarbeider |  | 3mo | 2028-04-24 | 2028-08-17 | 634FS+6w | 2028-03-07 | 2028-06-12 | 3mo | 331d |  |  | Uke 17 | 2028 |  |
| 636 | 1.18.3 | Møllendalsveien |  | 60d | 2028-05-02 | 2028-08-24 |  | 2028-05-02 | 2028-08-24 | 60d | 326d |  | start no earlier than 2028-05-02 | Uke 18 | 2028 |  |
| 637 | 1.19 | Sluttfase |  | 7mo | 2028-03-16 | 2028-11-07 | 411FS+10d | 2028-06-01 | 2028-11-08 | 4.7mo | 17d |  |  | Uke 11 | 2028 |  |
| 638 | 1.20 | Prøvedrift |  | 12.6mo | 2028-12-01 | 2029-11-27 | 637 | 2028-11-09 | 2029-10-18 | 12mo | 0d |  | must start on 2028-12-01 | Uke 48 | 2028 |  |
| 639 | 1.21 | Overtakelse av kontraktsarbeidet | milestone | 0d | 2029-11-27 | 2029-11-27 | 638 | 2029-10-18 | 2029-10-18 | 0d | 3d |  |  | Uke 48 | 2029 |  |
